# 3GPP_Work Plan

Schedule from MS Project, 2000-01-03 to 2006-06-15, A marks actual dates.

## Calendars

- Standard: Mon-Fri 08:00-12:00, 13:00-17:00; Sat-Sun off.

## Resources

| Resource | Rate |
| --- | --- |
| NP | 1141331000 |
| N1 |  |
| N2 |  |
| N3 |  |
| N4 |  |
| N5 |  |
| TP |  |
| T1 |  |
| T2 |  |
| T3 |  |
| RP |  |
| R1 |  |
| R2 |  |
| R3 |  |
| R4 |  |
| SP |  |
| S1 |  |
| S2 |  |
| S3 |  |
| S4 |  |
| S5 |  |
| PCG |  |
| GP |  |
| No |  |
| CN4 |  |
| ? |  |
| WG G2 |  |
| G2 |  |
| G1 |  |
| G4 |  |
| G3 |  |
| All |  |
| Generic |  |
| MLST |  |
| G5 |  |
| S3, G2 |  |
| WG T2 |  |
| GP,G1 |  |
| G4,G5 |  |
| OMA |  |
| GP-G2 |  |
| Yes |  |
| GP; |  |

## Schedule

| ID | WBS | Task | Duration | Start | Finish | Complete | Remaining | Baseline start | Baseline finish | Baseline duration | Total slack | Constraint | Resources | Work | Actual work | Text6 | Text9 | Text1 | Text4 | Text5 | Text7 | Text8 | Text11 | Text3 | Text2 | Text10 |
| --- | --- | --- | --- | --- | --- | --- | --- | --- | --- | --- | --- | --- | --- | --- | --- | --- | --- | --- | --- | --- | --- | --- | --- | --- | --- | --- |
| 1 | 1 | VERSION 2004 October 29th | 1d | 2000-01-03 | 2000-01-03 |  |  | 2000-01-03 | 2000-01-03 | 1d | 1682d |  |  |  |  | Rel | 2044 |  |  |  |  |  |  |  |  |  |
| 2 | 2 | "CTRL + a" to display all the 3GPP fields | 1d | 2000-01-03 | 2000-01-03 |  |  | 2000-01-03 | 2000-01-03 | 1d | 1682d |  |  |  |  |  | 1462 |  |  |  |  |  |  |  |  |  |
| 3 | 3 | Content of Rel-6 and Rel-7. Not frozen. | 1d | 2000-01-03 | 2000-01-03 |  |  | 2000-01-03 | 2000-01-03 | 1d | 1682d |  |  |  |  | Rel | 2058 |  |  |  |  |  |  |  |  |  |
| 5 | 4 | Rel-6 Evolutions of the transport in the UTRAN | 218d | 2003-03-03 | 2003-12-31 |  |  | 2003-03-03 | 2003-12-31 | 218d | 640d | start no earlier than 2003-03-03 | RP | 1744h |  | NA | Feat | ETRAN | Francois Courau, Alcatel | francois.courau@alcatel.fr | TSG | Cesar | Generic |  |  |  |
| 6 | 8 | **Rel-6 Improvements of Radio Interface** | 1262d? | 2000-08-14 A | 2005-06-15 | 83% | 219.28d? | 2000-08-14 | 2004-09-15 | 1068d | 261d |  | RP | 36040h | 28025h | Rel-6 |  | RInImp |  |  | TSG | Cesar |  |  |  |  |
| 7 | 5.1 | Improving Receiver Performance Requirements for the FDD UE | 401d | 2002-03-08 A | 2003-09-19 A | 100% |  | 2002-03-08 | 2003-09-19 | 401d |  | start no earlier than 2002-03-08 | R4 | 3208h | 3208h | Rel-6 | BB | RInImp-UERecPerf | Shimon Moshavi, Intel | shimon.moshavi@INTEL.COM | TSG |  | Active | TS25.101 |  |  |
| 8 | 8.2 | **Base station classification** | 603d | 2000-08-14 A | 2002-12-04 A | 100% |  | 2000-08-14 | 2002-12-04 | 603d |  |  | R4 | 9648h | 9648h | Rel-6 |  | RInImp-BSClass |  |  | TSG |  |  |  |  |  |
| 9 | 8.2.1 | FDD Base station classification | 603d | 2000-08-14 A | 2002-12-04 A | 100% |  | 2000-08-14 | 2002-12-04 | 603d |  | finish no earlier than 2002-12-04 | R4 | 4824h | 4824h | Rel-6 | 1476 | RInImp-BSClass-FDD | A. Toskala, Nokia |  | TSG |  |  | TS25.104, TS25.141 | BaAs |  |
| 10 | 5.3 | UMTS-850 | 266d | 2002-12-06 A | 2003-12-12 A | 100% |  | 2002-12-06 | 2003-12-12 | 266d |  | finish no earlier than 2003-12-15 | R4 | 2128h | 2128h | Rel-6 | BB | RInImp-UMTS850 | Don Zelmer, Cingular | don.zelmer@cingular.com | TSG | MCC_RAN | Active | TS25.101, 25.104, 25.133, 25.141, 25.307, 25.331, TR25.942 |  |  |
| 11 | 5.4 | DS-CDMA introduction in the 800 MHz band | 196d | 2003-03-14 A | 2003-12-12 A | 100% |  | 2003-03-14 | 2003-12-12 | 196d |  | finish no earlier than 2003-12-15 | R4 | 1568h | 1568h | Rel-6 | BB | RInImp-UMTS800 | Takehiro Nakamura, NTT DoCoMo | takehiro@wsp.yrp.nttdocomo.co.jp | TSG | MCC_RAN | Active | TS25.101, 25.104, 25.133, 25.141, 25.307, 25.331 |  |  |
| 12 | 5.5 | UMTS 1.7/2.1 GHz | 261d | 2003-03-14 A | 2004-03-12 A | 100% |  | 2003-03-14 | 2004-03-12 | 261d |  | finish no earlier than 2004-03-15 | R4 | 2088h | 2088h | Rel-6 | BB | RInImp-UMTS1721 | Jussi Numminen, Nokia | jussi.numminen@NOKIA.COM | TSG | MCC RAN | Active | TS25.101, 25.104, 25.133, 25.141, 25.307, 25.331 |  |  |
| 13 | 5.6 | **Improved Receiver Performance Requirements for HSDPA** | 392d? | 2003-12-15 A | 2005-06-15 | 25% | 293.89d? | 2003-12-15 | 2004-09-14 | 197d | 261d |  | R4 | 7304h | 1043.2h | Rel-6 |  | RInImp-HSPerf | Jussi Numminen, Nokia | jussi.numminen@NOKIA.COM | TSG | MCC RAN |  |  |  |  |
| 14 | 5.6.1 | Improved Minimum Performance Requirements for HSDPA UE categories 7 and 8 | 195d? | 2004-09-15 | 2005-06-15 |  |  |  |  |  | 261d | finish no earlier than 2005-06-15 | R4 | 1560h |  | Rel-6 |  | RInImp-HSPerf-10code | Jussi Numminen, Nokia | jussi.numminen@nokia.com | TSG | MCC_RAN |  | TS25.101 |  |  |
| 15 | 5.6.2 | Performance Requirements of Receive Diversity for HSDPA | 326d | 2003-12-15 A | 2005-03-15 | 40% | 195.6d | 2003-12-15 | 2004-09-14 | 197d | 327d | finish no earlier than 2005-03-15 | R4 | 2608h | 1043.2h | Rel-6 |  | RInImp-HSPerf-RxDiv | Takehiro Nakamura (NTT DoCoMo) | takehiro@wsp.yrp.nttdocomo.co.jp | TSG | MCC RAN |  | TS25.101 |  |  |
| 16 | 6 | **Rel-6 RAN Feasibility Studies** | 1197d? | 2000-08-14 A | 2005-03-15 | 88% | 148.6d? | 2000-08-14 | 2005-03-15 | 1197d | 326d |  | RP | 43064h | 31965.2h | Rel-6 |  |  |  |  |  | Cesar |  |  |  |  |
| 17 | 6.1 | FS of the improved access to UE measurement data for CRNC to support TDD RRM | 270d? | 2002-12-06 A | 2003-12-18 A | 100% |  | 2002-12-06 | 2003-12-18 | 270d? |  | finish no earlier than 2003-09-19 | R3 | 2160h | 2160h | Rel-6 |  | RANimp-RRMopt-FSUEMsD | Jim Miller, Interdigital | jim.miller@interdigital.com | TSG |  |  |  |  | SP-24 |
| 18 | 6.2 | FS on Radio link performance enhancements | 1067d | 2000-08-14 A | 2004-09-14 A | 100% |  | 2000-08-14 | 2004-06-15 | 1002d |  | finish no earlier than 2004-09-14 | R1 | 8536h | 8536h | Rel-6 | SI | RInImp-Rlperf | Antti Toskala, Nokia Networks | antti.toskala@nokia.com | TSG | MCC_RAN | Active | TR25.899 |  |  |
| 19 | 6.3 | FS on Improvement of inter-frequency and inter-system measurements for 1.28 Mcps TDD | 461d | 2001-12-14 A | 2003-09-19 A | 100% |  | 2001-12-14 | 2003-09-19 | 461d |  | start no earlier than 2001-12-14 | R1 | 3688h | 3688h | Rel-6 | SI | RInImp-IfIsMLCR | Li Xiao Qiang, SAMSUNG | xqli@samsung.co.kr | TSG |  | Active | TR25.888 |  |  |
| 20 | 6.4 | FS for the analysis of OFDM for UTRAN enhancement | 526d | 2002-06-10 A | 2004-06-14 A | 100% |  | 2002-06-10 | 2004-06-14 | 526d |  | start no earlier than 2002-06-10 | R1 | 4208h | 4208h | Rel-6 | SI | RInImp-FSOFDM | Sarah Boumendil, Nortel | boumendi@nortelnetworks.com | TSG | MCC_RAN | Active | TR25.892 |  |  |
| 21 | 6.5 | FS on Uplink Enhancements for Dedicated Transport Channels | 396d | 2002-09-06 A | 2004-03-12 A | 100% |  | 2002-09-06 | 2004-03-12 | 396d |  | finish no earlier than 2004-03-12 | R1 | 3168h | 3168h | Rel-6 | SI | RInImp-FSUpDTrCh | Karri Ranta-aho, Nokia | Karri.Ranta-aho@nokia.com | TSG | MCC_RAN | Active | TR25.896 |  |  |
| 22 | 6.6 | FS on Analysis on Higher Chip Rates for UTRA TDD evolutions | 528d | 2002-09-06 A | 2004-09-14 A | 100% |  | 2002-09-06 | 2004-06-14 | 462d |  | finish no earlier than 2004-09-14 | R1 | 4224h | 4224h | Rel-6 | SI | RInImp-FSVHCRTDD | Tim Wilkinson, IPWireless | mbeale@ipwireless.com | TSG | MCC_RAN | Active | TR25.895 |  |  |
| 23 | 6.7 | FS on Low Output Powers for general purpose FDD BSs | 128d | 2003-06-13 A | 2004-03-12 A | 100% |  | 2003-06-13 | 2004-03-12 | 128d |  | finish no earlier than 2004-03-12 | R3 | 1024h | 1024h | Rel-6 | SI | RInImp-FSLoPw | Ana Burgos, Telefonica | burgos_a@tsm.es | TSG | MCC_RAN | Active | TR25.807 |  |  |
| 24 | 6.8 | FS on Uplink enhancements for UTRA TDD | 398d | 2003-06-06 A | 2004-12-15 | 65% | 139.3d | 2003-06-06 | 2004-09-14 | 333d | 391d | finish no earlier than 2004-12-15 | R1 | 3184h | 2069.6h | Rel-6 | SI | RInImp-FSUpEnhTDD | Marian Rudolf, Interdigital | Marian.Rudolf@InterDigital.com | TSG | MCC_RAN | Active | TR25.804 |  |  |
| 25 | 8.8 | FS on UE antenna efficiency test methods performance requirements (2) | 131d | 2002-03-08 A | 2002-09-06 A | 100% |  | 2002-03-08 | 2002-09-06 | 131d |  | finish no earlier than 2002-09-06 | R4 | 1048h | 1048h | Rel-6 |  | RInImp-UEAnTM2 | Alf Ahlström, Allgon |  | TSG |  |  |  |  |  |
| 26 | 9.4 | FS on the evolution of the UTRAN architecture | 657d | 2002-09-09 A | 2005-03-15 | 35% | 427.05d | 2002-09-09 | 2005-03-15 | 657d | 326d | finish no earlier than 2005-03-15 | R3 | 5256h | 1839.6h | Rel-6 |  | RANimp-FSEvo | Woonhee Hwang, Nokia | Antti.Toskala@nokia.com | TSG | MCC_RAN |  |  |  |  |

Notes:
- 5: Generic feature
- 6: This is a generic feature without particular end date
- 14: Approved at RP#25 as RP-040375
- 18: Study finished at RP#25
- 22: Study finished at RP#25
- 25: The RInImp-UEAnTM FS was re-opened at TSG RAN#15 upon request from WG4
- 26: Work stopped until completion of MBMS in RAN3

| ID | WBS | Task | Duration | Start | Finish | Complete | Remaining | Baseline start | Baseline finish | Baseline duration | Total slack | Constraint | Resources | Work | Actual work | Text1 | Text4 | Text6 | Text7 | Text8 | Text9 | Text11 | Text3 | Text5 | Text2 | Text12 | Text10 |
| --- | --- | --- | --- | --- | --- | --- | --- | --- | --- | --- | --- | --- | --- | --- | --- | --- | --- | --- | --- | --- | --- | --- | --- | --- | --- | --- | --- |
| 27 | 7 | **FDD Enhanced Uplink** | 327d | 2004-03-15 A | 2005-06-15 | 30% | 227.86d | 2004-03-15 | 2005-06-15 | 327d | 261d |  | RP | 11536h | 2704.4h | EDCH | Joakim Bergström (Ericsson) | Rel-6 | TSG | Cesar | Feat | Active |  |  |  |  |  |
| 28 | 7.1 | FDD Enhanced Uplink - Stage 2 | 197d | 2004-03-15 A | 2004-12-15 | 80% | 39.4d | 2004-03-15 | 2004-03-15 | 1d | 391d | finish no earlier than 2004-12-15 | R2 | 1576h | 1260.8h | EDCH-Stage2 |  | Rel-6 | TSG |  |  |  | TS 25.309 |  |  |  |  |
| 29 | 7.2 | FDD Enhanced Uplink - Physical Layer | 197d | 2004-03-15 A | 2004-12-15 | 30% | 137.9d | 2004-03-15 | 2004-12-15 | 197d | 391d | finish no earlier than 2004-12-15 | R1 | 1576h | 472.8h | EDCH-Phys | Karri Ranta-aho (Nokia) | Rel-6 | TSG | MCC RAN | BB | Active | TS25.211, 25.212, 25.213, 25.214, 25.215 |  |  |  |  |
| 30 | 7.3 | FDD Enhanced Uplink - Layer 2 and 3 Protocol Aspects | 197d | 2004-03-15 A | 2004-12-15 | 40% | 118.2d | 2004-03-15 | 2004-12-15 | 197d | 391d | finish no earlier than 2004-12-15 | R2 | 1576h | 630.4h | EDCH-L23 | Joakim Bergström (Ericsson) | Rel-6 | TSG | MCC RAN | BB | Active | TS25.301, 25.302, 25.306, 25.321, 25.331 |  |  |  |  |
| 31 | 7.4 | FDD Enhanced Uplink - UTRAN Iub/Iur Protocol Aspects | 197d | 2004-03-15 A | 2004-12-15 | 5% | 187.15d | 2004-03-15 | 2004-12-15 | 197d | 391d | finish no earlier than 2004-12-15 | R3 | 1576h | 78.8h | EDCH-IurIub | Saso Stojanovski (Nortel) | Rel-6 | TSG | MCC RAN | BB | Active | TS25.401, 25.420, 25.423, 25.430, 25.433 |  |  |  |  |
| 32 | 7.5 | FDD Enhanced Uplink - RF Radio Transmission/ Reception, System Performance Requirements and Conformance Testing | 327d | 2004-03-15 A | 2005-06-15 | 10% | 294.3d | 2004-03-15 | 2005-06-15 | 327d | 261d | finish no earlier than 2005-06-15 | R4 | 2616h | 261.6h | EDCH-RF | Thomas Unshelm (Ericsson) | Rel-6 | TSG | MCC RAN | BB | Active | TS25.101, 25.104, 25.133, 25.141 | thomas.unshelm@ERICSSON.COM |  |  |  |
| 33 | 9 | **Rel-6 RAN improvements** | 712d? | 2002-03-25 A | 2004-12-15 | 59% | 288.5d? | 2002-09-09 | 2004-12-15 | 592d? | 391d |  | RP | 29824h | 16015.3h | RANimp |  | Rel-6 | TSG | Cesar |  |  |  |  |  |  |  |
| 34 | 9.2 | **RAB support enhancement** | 712d? | 2002-03-25 A | 2004-12-15 | 20% | 569.22d? | 2003-03-14 | 2004-12-15 | 458d? | 391d |  | R2 | 11384h | 2282.84h | RANimp-RABSE | Juha Mikola, Nokia | Rel-6 | TSG | MCC RAN | 624 |  | TR 25.862 | juha.mikola@nokia.com | BaAS |  |  |
| 35 | 8.1.1 | Iu enhancements for IMS support in RAN | 320d? | 2003-03-14 A | 2004-06-03 | 25% | 240d? | 2003-03-14 | 2004-12-15 | 458d? | 529d | start no earlier than 2003-03-14 | R3 | 2560h | 640h | RANimp-RABSE-IuEnhIMS | Phillipe Godin, Nortel | Rel-6 | TSG | MCC RAN |  |  |  | Philippe.Godin@nortelnetworks.com |  |  |  |
| 36 | 8.1.2 | Optimisation of downlink channelisation code utilisation | 198d | 2004-03-12 A | 2004-12-14 | 5% | 188.1d | 2004-03-12 | 2004-12-15 | 198d | 391d | start no earlier than 2004-03-12 | R1 | 1584h | 79.2h | RANimp-RABSE-CodeOptFDD | Sarah Boumendil (Nortel Networks) | Rel-6 | TSG | MCC RAN | WT | Active |  | boumendi@nortelnetworks.com |  |  |  |
| 37 | 8.1.3 | Optimisation of channelisation code utilisation for TDD | 197d | 2004-03-15 | 2004-12-15 |  |  | 2004-03-15 | 2004-12-15 | 197d | 391d | finish no earlier than 2004-12-15 | R1 | 1576h |  | RANimp-RABSE-CodeOptTDD | Nicholas Anderson (IPWireless) | Rel-6 | TSG | MCC RAN | WT | Active |  |  |  |  |  |
| 38 | 8.1.4 | HS-DPCCH ACK/NACK Enhancement | 65d? | 2004-09-15 | 2004-12-15 |  |  |  |  |  | 391d | finish no earlier than 2004-12-15 | R1 | 520h |  | RANimp-RABSE-ACKNACK | Jussi Kähtävä, Nokia | Rel-6 | TSG | MCC_RAN |  |  | TS25.212, TS25.214, TS24.331, TS25.433 |  |  |  |  |
| 39 | 8.1.5 | Deleted - Improvement of RRM across RNS and RNS/BSS | 445d? | 2002-03-25 A | 2003-12-05 | 35% | 289.25d? |  |  |  | 658d | finish no earlier than 2003-12-05 | R3 | 3560h | 1246h | RANimp-RRM1 | Antti Toskala, Nokia | Rel-6 |  |  |  |  |  |  |  | RP-23 |  |
| 40 | 9.1 | Beamforming Enhancements | 66d | 2003-09-19 A | 2003-12-19 A | 100% |  | 2003-09-19 | 2003-12-19 | 66d |  | finish no earlier than 2004-03-12 | R1 | 528h | 528h | RANimp-BFE | Jussi Kähtävä, Nokia | Rel-6 | TSG | MCC_RAN |  |  | TS24.215, 25.423, 25.425, 25.433, 25.435 | jussi.kahtava@nokia.com |  |  |  |
| 41 | 8.3 | **Rel6 RRM optimization for Iur and Iub** | 126d | 2003-09-19 A | 2004-03-12 A | 100% |  | 2003-09-19 | 2004-03-12 | 126d |  |  | R3 | 2016h | 2016h | RANimp-RRMopt | Gert-Jan van Lieshout, Ericsson | Rel-6 | TSG | MCC_RAN |  |  |  | Gert-Jan.van.Lieshout@eln.ericsson.se | BaAS |  |  |
| 42 | 8.3.1 | Deleted- Improved access to UE measurement data for CRNC to support TDD RRM | 126d | 2003-09-19 A | 2004-03-12 A | 100% |  | 2003-09-19 | 2004-03-12 | 126d |  | finish no earlier than 2004-03-15 | R3 | 1008h | 1008h | RANimp-RRMopt-UEMsD | Jim Miller, Interdigital | Rel-6 | TSG | MCC RAN | WT | Active | TS25.423 | jim.miller@interdigital.com |  | RP-22 |  |
| 43 | 8.4 | **Remote Control of Electrical Tilting Antennas** | 395d? | 2003-03-14 A | 2004-09-16 | 99% | 0d? | 2003-03-14 | 2004-09-16 | 395d? | 0d |  | R3 | 7464h | 5428.47h | RANimp-TiltAnt | Andreas Hauser, Vodafone | Rel-6 | TSG | MCC_RAN |  |  |  | Andreas.Hauser@vodafone.com |  |  |  |
| 44 | 8.4.1 | Tilting Antenna - RAN aspects | 393d? | 2003-03-14 A | 2004-09-14 A | 100% |  | 2003-03-14 | 2004-09-15 | 394d? |  | finish no earlier than 2004-09-14 | R3 | 3144h | 3144h | RANimp-TiltAnt | Andreas Hauser, Vodafone | Rel-6 | TSG | MCC_RAN |  |  | TS25.460, 25.461, 25.462, 25.463 | Andreas.Hauser@vodafone.com |  |  |  |
| 45 | 8.4.2 | OAM&P impacts | 145d | 2004-02-27 A | 2004-09-16 A | 100% |  | 2004-02-27 | 2004-09-16 | 145d |  | finish no earlier than 2004-09-16 | S5 | 1160h | 1160h | RANimp-TiltAnt-OAM | John MUDGE, Vodafone | Rel-6 | WG | Adrian |  |  | 32.804, 32.xyz | john.mudge@vodafone.co.uk |  |  | SP-24 |
| 46 | 8.5 | Network Assisted Cell Change (NACC) from UTRAN to GERAN - network-side aspects | 462d? | 2002-09-09 A | 2004-06-15 A | 100% |  | 2002-09-09 | 2004-06-15 | 462d? |  | finish no earlier than 2004-06-15 | R3 | 3696h | 3696h | RANimp-NACC | Brendan McWilliams, Vodafone | Rel-6 | TSG | MCC_RAN |  |  |  | Brendan.McWilliams@gb.vodafone.co.uk |  |  |  |
| 47 | 12 | **Location Services enhancements 2** | 1124d? | 2000-08-28 A | 2004-12-16 | 78% | 242.39d? | 2000-08-28 | 2004-10-29 | 1090d? | 389d |  | S2 | 83792h | 59830.8h | LCS2 |  | Rel-6 | TSG | Sang-Ui |  |  | 23.271 |  |  |  |  |
| 48 | 12.1 | **Improvement on Le interface** | 653d? | 2002-06-17 A | 2004-12-15 | 76% | 158.47d? | 2002-06-17 | 2004-10-29 | 620d? | 390d |  | S2 | 9872h | 7476.21h |  |  | Rel-6 | TSG |  |  |  |  |  |  |  |  |
| 49 | 9.1.1 | Stage 2 | 331d? | 2002-06-17 A | 2003-09-22 A | 100% |  | 2002-06-17 | 2003-09-22 | 331d? |  | start no earlier than 2002-06-17 | S2 | 2648h | 2648h |  |  | Rel-6 |  |  |  |  |  |  |  |  |  |
| 50 | 9.1.2 | Stage 3 - impacts MLP (Mobile Location Protocol) | 250d? | 2004-01-01 A | 2004-12-15 | 44% | 141d? | 2003-07-10 | 2004-10-29 | 342d? | 390d | finish no earlier than 2004-12-15 | OMA | 2000h | 872h |  |  | Rel-6 |  |  |  |  |  | OMA-LIAISON@mail.openmobilealliance.org |  |  |  |

Notes:
- 33: Generic feature
- 34: This is a building block without particular end date
- 35: Closed RAN#24 due to the lack of progress
- 38: Approved at RP#25 as RP-040390
- 39: abandoned RP-23
- 44: Finished at RP#25
- 45: az: WID approved at SA5#37 (02/2004)
- 50: Updated according to SP-040232

| ID | WBS | Task | Duration | Start | Finish | Complete | Remaining | Baseline start | Baseline finish | Baseline duration | Total slack | Constraint | Resources | Work | Actual work | Text6 | Text7 | Text5 | Text1 | Text8 | Text4 | Text9 | Text12 | Text2 |
| --- | --- | --- | --- | --- | --- | --- | --- | --- | --- | --- | --- | --- | --- | --- | --- | --- | --- | --- | --- | --- | --- | --- | --- | --- |
| 51 | 12.2 | **Enhanced support for anonymity and user privacy** | 638d? | 2002-07-08 A | 2004-12-15 | 72% | 178.13d? | 2002-07-08 | 2004-10-29 | 605d? | 390d |  | S2 | 9144h | 6590.92h | Rel-6 | TSG |  |  |  |  |  |  |  |
| 52 | 9.2.1 | Stage 2 | 255d? | 2002-07-08 A | 2003-06-27 A | 100% |  | 2002-07-08 | 2003-06-27 | 255d? |  | finish no earlier than 2003-06-27 | S2 | 2040h | 2040h | Rel-6 |  |  |  |  |  |  |  |  |
| 53 | 9.2.2 | Stage 3 - impacts MLP and RLP | 250d? | 2004-01-01 A | 2004-12-15 | 44% | 141d? | 2003-07-10 | 2004-10-29 | 342d? | 390d | finish no earlier than 2004-12-15 | OMA | 2000h | 872h | Rel-6 |  | OMA-LIAISON@mail.openmobilealliance.org |  |  |  |  |  |  |
| 54 | 12.3 | **Enhanced inter-GMLC interface** | 648d? | 2002-06-24 A | 2004-12-15 | 91% | 60.79d? | 2002-06-24 | 2004-10-29 | 615d? | 390d |  | S2 | 9704h | 8793.71h | Rel-6 | TSG |  |  |  |  |  |  |  |
| 55 | 9.3.1 | Stage 2 | 315d? | 2002-06-24 A | 2003-09-05 A | 100% |  | 2002-06-24 | 2003-09-05 | 315d? |  | finish no earlier than 2003-09-05 | S2 | 2520h | 2520h | Rel-6 |  |  |  |  |  |  |  |  |
| 56 | 9.3.2 | Stage 3 - definition of RLP and PCP | 250d? | 2004-01-01 A | 2004-12-15 | 79% | 53d? | 2002-09-02 | 2004-10-29 | 565d? | 390d | finish no earlier than 2004-12-15 | OMA | 2000h | 1576h | Rel-6 |  | OMA-LIAISON@mail.openmobilealliance.org |  |  |  |  |  |  |
| 57 | 12.4 | **Location Services support for IMS public identities** | 473d? | 2003-02-24 A | 2004-12-15 | 89% | 51.16d? | 2002-09-02 | 2004-10-29 | 565d? | 390d |  | S2 | 7704h | 5022.55h | Rel-6 | TSG |  |  |  |  |  |  |  |
| 58 | 9.4.1 | Stage 2 | 240d? | 2003-02-24 A | 2004-01-23 A | 100% |  | 2003-02-24 | 2004-01-23 | 240d? |  | finish no earlier than 2004-01-23 | S2 | 1920h | 1920h | Rel-6 |  |  |  |  |  |  |  |  |
| 59 | 9.4.2 | Stage 3 - impacts MLP, RLP and PCP | 250d? | 2004-01-01 A | 2004-12-15 | 79% | 53d? | 2002-09-02 | 2004-10-29 | 565d? | 390d | finish no earlier than 2004-12-15 | OMA | 2000h | 1576h | Rel-6 |  | OMA-LIAISON@mail.openmobilealliance.org |  |  |  |  |  |  |
| 60 | 12.5 | **New area event for location service triggering reports** | 663d? | 2002-06-03 A | 2004-12-15 | 80% | 132.51d? | 2002-06-03 | 2004-10-29 | 630d? | 390d |  | S2 | 11416h | 7122.43h | Rel-6 | TSG |  |  |  |  |  |  |  |
| 61 | 9.5.1 | Stage 2 | 280d? | 2002-06-03 A | 2003-06-27 A | 100% |  | 2002-06-03 | 2003-06-27 | 280d? |  | finish no earlier than 2003-06-27 | S2 | 2240h | 2240h | Rel-6 |  |  |  |  |  |  |  |  |
| 62 | 9.5.2 | Stage 3 for UE-CN signalling | 234d? | 2003-10-09 A | 2004-08-31 | 95% | 11.7d? | 2003-10-09 | 2004-08-31 | 234d? | 466d | start no earlier than 2003-10-09 | N4 | 1872h | 1778.4h | Rel-6 |  |  |  |  |  |  |  |  |
| 63 | 9.5.3 | Stage 3 - impacts MLP, RLP and PCP | 250d? | 2004-01-01 A | 2004-12-15 | 44% | 141d? | 2003-07-14 | 2004-10-29 | 340d? | 390d | finish no earlier than 2004-12-15 | OMA | 2000h | 872h | Rel-6 |  | OMA-LIAISON@mail.openmobilealliance.org |  |  |  |  |  |  |
| 64 | 12.7 | **UE positioning** | 1057d? | 2000-08-28 A | 2004-09-14 | 72% | 295.72d? | 2000-08-28 | 2004-09-15 | 1058d? | 456d |  | RP | 24920h | 15751h | Rel-6 | TSG |  | LCS2-UEpos | MCC_RAN |  |  |  |  |
| 65 | 12.8 | Open SMLC-SRNC Interface within the UTRAN to support UTRAN Rel4 positioning methods | 700d? | 2001-01-15 A | 2003-09-19 A | 100% |  | 2001-01-15 | 2003-09-19 | 700d? |  | finish no earlier than 2003-09-19 | R2 | 5600h | 5600h | Rel-6 | TSG | Meik.Kottkamp@siemens.com | LCS-Rel4Pos |  | Meik Kottkamp, Siemens | 2475 |  |  |
| 66 | 9.6.2 | A-GPS minimum performance specification | 333d? | 2003-06-06 A | 2004-09-14 A | 100% |  | 2003-06-06 | 2004-09-15 | 334d? |  | finish no earlier than 2004-09-14 | R4 | 2664h | 2664h | Rel-6 | TSG | donglin.shen@attws.com | LCS-UEPos-AGPSPerf | MCC_RAN | Donglin Shen, AT&T Wireless Services |  |  |  |
| 67 | 12.7.2 | FS on Enhancements to OTDOA Positioning using advanced blanking methods | 320d | 2002-07-01 A | 2003-09-19 A | 100% |  | 2002-07-01 | 2003-09-19 | 320d |  | finish no earlier than 2003-09-19 | R2 | 2560h | 2560h | Rel-6 | TSG | david.bartlett@cursor-system.com | LCS2-UEpos-FSBlank |  | David Bartlett, Cambridge Positioning Systems |  |  |  |
| 68 | 9.6.4 | Deleted - UE positioning enhancements - other methods | 805d? | 2000-08-28 A | 2003-09-26 | 25% | 603.75d? |  |  |  | 708d | finish no earlier than 2003-09-26 | R2 | 6440h | 1610h | Rel-6 |  |  | LCS2-UEpos-enh |  | Meik Kottkamp, Siemens |  | RP-24 |  |
| 69 | 9.7 | LCS charging | 455d? | 2003-03-21 A | 2004-12-16 | 90% | 45.5d? |  |  |  | 389d | start no earlier than 2003-03-21 | S5 | 3640h | 3276h | Rel-6 | TSG |  | LCS2-CH |  |  |  |  |  |
| 70 | 14 | **Rel-6 Security enhancements** | 903d? | 2001-01-03 A | 2004-06-18 | 38% | 559.78d? | 2001-01-03 | 2004-06-18 | 903d? | 518d |  | S3 | 26984h | 9747.78h | Rel-6 | TSG | Peter.Howard@vodafone.com | SEC1 | Maurice | Peter Howard, Vodafone |  |  |  |
| 71 | 14.1 | **Enhanced HE control of security (including positive authentication reporting)** | 712d | 2001-01-03 A | 2003-09-25 | 23% | 545d | 2001-01-03 | 2003-09-25 | 712d | 709d |  | S3 | 14064h | 4008h | Rel-6 |  | Peter.Howard@vodafone.com |  |  | Peter Howard, Vodafone | 2026 |  |  |
| 72 | 14.1.1 | Stage 2 | 378d | 2001-01-03 | 2002-06-14 |  |  | 2001-01-03 | 2002-06-14 | 378d | 1043d | finish no earlier than 2002-06-14 | S3 | 3024h |  | Rel-6 |  |  |  |  |  | 2027 |  |  |
| 73 | 14.1.3 | **Network domain security** | 334d | 2002-06-17 A | 2003-09-25 | 50% | 167d | 2002-06-17 | 2003-09-25 | 334d | 709d |  | S3 | 5344h | 2672h | Rel-6 | TSG | Geir-myrdahl.koien@telenor.com | SEC1-NDS |  | Geir M. Køien, Telenor |  |  | Sec |
| 74 | 14.1.3.1 | IP network layer security (NDS/IP) | 334d | 2002-06-17 A | 2003-09-25 | 50% | 167d | 2002-06-17 | 2003-09-25 | 334d | 709d | finish no earlier than 2003-09-25 | S3 | 2672h | 1336h | Rel-6 | WG |  | SEC1-NDS-IP |  |  |  |  |  |
| 75 | 10.2 | Network Domain Security; Authentication Framework (NDS/AF) | 521d? | 2002-02-15 A | 2004-02-13 | 70% | 156.3d? | 2002-02-15 | 2004-02-13 | 521d? | 608d | finish no earlier than 2004-02-13 | S3 | 4168h | 2917.6h | Rel-6 | TSG | tommi.viitanen@nokia.com | SEC1-NDS-AF |  | Tommi Viitanen, Nokia |  |  |  |
| 76 | 10.3 | Key Management of group keys for Voice Group Call Services | 191d | 2003-09-26 A | 2004-06-18 | 5% | 181.45d | 2003-09-26 | 2004-06-18 | 191d | 518d | finish no earlier than 2004-06-18 | S3 | 1528h | 76.4h | Rel-6 | TSG | benno.tietz@vodafone.com | SECGKYV | Maurice | Benno Tietz, Vodafone D2 |  |  |  |

Notes:
- 53: Updated according to SP-040232
- 56: Updated according to SP-040232
- 59: Updated according to SP-040232
- 62: 31/10/2003 work has started. Current stage 3 fullfills the requirements of stage 2. ......
- 63: Updated according to SP-040232
- 65: Text3: TS25.305, 25.401, 25.450, 25.452, 25.453
- 66: Finished at RP#25 / Text3: TS25.171
- 68: This is a building block without particular end date
- 69: SA#25 09/2004 completed / Text3: 32.271
- 70: Added BB UE authentication and rapporteur added.
- 71: Added by P-000575 without any dates. 18/10/00: Change of WI title, added hyperlink rapporteur new end date 03/01. New end date and correct Release to be decided S3#18
- 72: New end date and correct Release to be decided S3#18
- 73: WID approved for Rel-6 at SA#17
- 74: Should be complete after SA3#27 / Text3: TS 33.210
- 75: WID approved SA#19. Work started after FS approved SA#18
- 76: Approved TSG#21 / Text3: 42.068, 43.068, 44.068, 42.069, 43.069, 44.069, 31.102, 24.008, 48.008, 42.009, 43.020

| ID | WBS | Task | Duration | Start | Finish | Complete | Remaining | Baseline start | Baseline finish | Baseline duration | Total slack | Constraint | Resources | Work | Actual work | Text1 | Text3 | Text6 | Text7 | Text8 | Text4 | Text5 | Text2 | Text9 | Text12 |
| --- | --- | --- | --- | --- | --- | --- | --- | --- | --- | --- | --- | --- | --- | --- | --- | --- | --- | --- | --- | --- | --- | --- | --- | --- | --- |
| 77 | 16 | **IMS Phase 2** | 1264d? | 2000-08-28 A | 2005-06-30 | 85% | 193.39d? | 2000-08-28 | 2004-11-30 | 1112d? | 249d |  | S1 | 119400h | 95290.3h | IMS2 | 23.228 | Rel-6 | TSG | Sang-Ui |  |  |  |  |  |
| 78 | 11.1 | Enhancements to the Cx and Sh interfaces | 323d? | 2003-06-06 A | 2004-08-31 | 95% | 16.15d? | 2003-06-06 | 2004-08-31 | 323d? | 466d | finish no earlier than 2004-08-31 | N4 | 2584h | 2454.8h | IMS2-CCR |  | Rel-6 | WG |  |  |  |  |  |  |
| 79 | 16.12 | **IMS Group Management** | 715d? | 2002-03-14 A | 2004-12-08 | 88% | 85.31d? | 2002-03-14 | 2004-09-08 | 650d? | 395d |  | S1 | 12680h | 11167.1h | IMSGM |  | Rel-6 | TSG |  | Juha Kalliokulju (Nokia) | juha.kalliokulju@nokia.com |  |  |  |
| 80 | 16.12.1 | Stage 1 - TS on IMS group management | 193d | 2002-03-14 A | 2002-12-09 A | 100% |  | 2002-03-14 | 2002-12-09 | 193d |  | finish no earlier than 2002-12-09 | S1 | 1544h | 1544h |  |  | Rel-6 | TSG |  | Juha Kalliokulju (Nokia) | juha.kalliokulju@nokia.com |  |  |  |
| 81 | 11.2.2 | Stage 2 | 158d? | 2003-05-26 A | 2003-12-31 A | 100% |  | 2003-05-26 | 2003-12-31 | 158d? |  | finish no earlier than 2003-12-31 | S2 | 1264h | 1264h |  |  | Rel-6 |  |  |  |  |  |  |  |
| 82 | 11.2.3 | Stage 3 for IMS Group management (e.g. chat) | 519d? | 2002-12-13 A | 2004-12-08 | 80% | 103.8d? | 2002-12-13 | 2004-09-08 | 454d? | 395d | finish no earlier than 2004-12-08 | N1 | 4152h | 3321.6h |  |  | Rel-6 |  |  | Keith Drage, Lucent | drage@lucent.com |  |  |  |
| 83 | 11.3 | **IMS Conferencing** | 548d? | 2002-11-04 A | 2004-12-08 | 91% | 51.9d? | 2002-11-04 | 2004-09-08 | 483d? | 395d |  | N1 | 10960h | 9922h |  |  | Rel-6 |  |  |  |  |  |  |  |
| 84 | 11.3.1 | Stage 2 | 303d? | 2002-11-04 A | 2003-12-31 A | 100% |  | 2002-11-04 | 2003-12-31 | 303d? |  | finish no earlier than 2003-12-31 | S2 | 2424h | 2424h |  |  | Rel-6 |  |  |  |  |  |  |  |
| 85 | 11.3.2 | Stage 3 | 519d? | 2002-12-13 A | 2004-12-08 | 85% | 77.85d? | 2002-12-13 | 2004-09-08 | 454d? | 395d | finish no earlier than 2004-12-08 | N1 | 4152h | 3529.2h |  |  | Rel-6 |  |  | Keith Drage, Lucent | drage@lucent.com |  |  |  |
| 86 | 16.11 | **IMS Messaging** | 861d? | 2002-03-14 A | 2005-06-30 | 66% | 295.36d? | 2002-03-14 | 2004-09-08 | 650d? | 249d |  | S1 | 21816h | 14332.1h | IMSM |  | Rel-6 | TSG |  | Juha Kalliokulju (Nokia) | juha.kalliokulju@nokia.com |  |  |  |
| 87 | 16.11.1 | TR on support of messaging in the IMS | 193d | 2002-03-14 A | 2002-12-09 A | 100% |  | 2002-03-14 | 2002-12-09 | 193d |  | finish no earlier than 2002-12-09 | S1 | 1544h | 1544h | IMSM-TR |  | Rel-6 | TSG |  | Juha Kalliokulju (Nokia) | juha.kalliokulju@nokia.com |  |  |  |
| 88 | 11.4.2 | Stage 1 22.340 | 23d? | 2002-11-11 A | 2002-12-11 A | 100% |  | 2002-11-11 | 2002-12-11 | 23d? |  | finish no earlier than 2002-12-11 | S1 | 184h | 184h | IMSM-TS | 22.340 | Rel-6 | TSG |  | Juha Kalliokulju (Nokia) | juha.kalliokulju@nokia.com |  |  |  |
| 89 | 11.4.3 | CRs to 22.140 & 22.228 | 263d? | 2002-03-14 A | 2003-03-17 A | 100% |  | 2002-03-14 | 2003-03-17 | 263d? |  | finish no earlier than 2003-03-17 | S1 | 2104h | 2104h | IMSM-CR | 22.140,22.228 | Rel-6 | TSG |  | Juha Kalliokulju (Nokia) | juha.kalliokulju@nokia.com |  |  |  |
| 90 | 16.11.3 | Stage 2 | 477d | 2002-11-04 A | 2004-08-31 A | 100% |  | 2002-11-04 | 2004-08-31 | 477d |  | finish no earlier than 2004-08-31 | S2 | 3816h | 3816h |  |  | Rel-6 |  |  |  |  |  |  |  |
| 91 | 11.4.5 | Stage 3 for IMS Messaging | 519d? | 2002-12-13 A | 2004-12-08 | 52% | 249.12d? | 2002-12-13 | 2004-09-08 | 454d? | 395d | finish no earlier than 2004-12-08 | N1 | 4152h | 2159.04h |  |  | Rel-6 |  |  | Keith Drage, Lucent | drage@lucent.com |  |  |  |
| 92 | 11.4.6 | SIP/SIMPLE Instant messaging | 391d? | 2004-01-01 | 2005-06-30 |  |  | 2004-01-01 | 2004-06-30 | 130d? | 249d | finish no earlier than 2005-06-30 | OMA | 3128h |  |  |  | Rel-6 | n/a |  |  | OMA-LIAISON@mail.openmobilealliance.org |  |  |  |
| 93 | 11.5 | **Additional SIP Capabilities support not covered by Rel-5** | 478d? | 2002-11-11 A | 2004-09-08 | 97% | 13.75d? | 2002-11-11 | 2004-09-08 | 478d? | 460d |  | N1 | 10136h | 9844.38h |  |  | Rel-6 |  |  |  |  |  |  |  |
| 94 | 11.5.1 | Stage 2 for add SIP cap (e.g. forking) | 335d? | 2002-11-11 A | 2004-02-20 A | 100% |  | 2002-11-11 | 2004-02-20 | 335d? |  | finish no earlier than 2004-02-20 | S2 | 2680h | 2680h |  |  | Rel-6 |  |  |  |  |  |  |  |
| 95 | 11.5.2 | Stage 3 for Additional SIP Capabilities | 454d? | 2002-12-13 A | 2004-09-08 | 95% | 22.7d? | 2002-12-13 | 2004-09-08 | 454d? | 460d | finish no earlier than 2004-09-08 | N1 | 3632h | 3450.4h |  |  | Rel-6 |  |  | Keith Drage, Lucent | drage@lucent.com |  |  |  |
| 96 | 11.6 | Review additional SIP Capabilities against IMS | 454d? | 2002-12-13 A | 2004-09-08 A | 100% |  | 2002-12-13 | 2004-03-12 | 326d? |  | finish no earlier than 2004-09-08 | N1 | 3632h | 3632h |  |  | Rel-6 |  |  | Keith Drage, Lucent | drage@lucent.com |  |  |  |
| 97 | 16.5 | **Interworking between IMS and IP networks** | 1118d? | 2000-08-28 A | 2004-12-08 | 88% | 131.76d? | 2000-08-28 | 2004-09-10 | 1055d? | 395d |  | N3 | 31712h | 22204.8h | IMS-CCR-IWIP | 23.821, 29.061, 29.162 | Rel-6 | TSG |  | Nigel Holland, BT | nigel.holland@bt.com | BaAS | 2048 |  |
| 98 | 16.5.1 | Interworking for 3GPP_SIP and IETF_SIP | 730d | 2000-08-28 A | 2003-06-13 A | 100% |  | 2000-08-28 | 2003-06-13 | 730d |  | finish no earlier than 2003-06-13 | N3 | 5840h | 5840h |  | New TR 29.962 | Rel-6 |  |  | Thomas Belling, Siemens |  |  |  |  |
| 99 | 16.5.2 | Interworking for IPv6 to IPv4 | 1118d | 2000-08-28 A | 2004-12-08 | 70% | 335.4d | 2000-08-28 | 2004-09-10 | 1055d | 395d | finish no earlier than 2004-12-08 | N3 | 8944h | 6260.8h |  | 29.163 | Rel-6 |  |  |  |  |  |  |  |
| 100 | 11.7.3 | Interworking for IPv6 to IPv4 (SIP / SDP aspects) | 87d? | 2004-05-11 A | 2004-09-08 A | 100% |  | 2004-05-11 | 2004-09-08 | 87d? |  | finish no earlier than 2004-09-08 | N1 | 696h | 696h |  |  | Rel-6 |  |  |  |  |  |  |  |
| 101 | 16.8.1 | stage 3 of interworking with non-IMS IP networks | 911d | 2001-03-14 A | 2004-09-08 A | 100% |  | 2001-03-14 | 2004-09-08 | 911d |  | finish no earlier than 2004-09-08 | N1 | 7288h | 7288h |  |  | Rel-6 |  |  |  |  |  |  |  |
| 102 | 16.6.1 | Interworking between IMS and CS networks | 929d? | 2000-08-28 A | 2004-03-18 A | 100% |  | 2000-08-28 | 2004-03-18 | 929d? |  | finish no earlier than 2004-03-18 | N3 | 7432h | 7432h | IMS-CCR-IWCS | 29.163, 29.061, 24.228, and new CN4 specification | Rel-6 | TSG |  | Brendan Mc Williams, Vodafone | brendan.mcwilliams@vf.vodafone.co.uk | CCaR |  |  |
| 103 | 16.10 | Mn interface (IM-MGW to MGCF) enhancements (CN4 Part) | 418d | 2001-08-07 A | 2004-09-01 | 85% | 62.7d | 2001-08-07 | 2004-09-01 | 418d | 465d | finish no earlier than 2004-09-01 | N4 | 3344h | 2842.4h | IMS-CCR-Mn |  | Rel-6 |  |  |  |  |  |  |  |
| 104 | 11.10 | Study of subscriber and operators relationship in IMS and related ISIM requirements for Rel 6” | 20d? | 2002-11-15 A | 2002-12-12 A | 100% |  | 2002-11-15 | 2002-12-12 | 20d? |  | finish no earlier than 2002-12-12 | S1 | 160h | 160h |  |  | Rel-6 |  |  | Juha Kalliokulju (Nokia) | juha.kalliokulju@nokia.com |  |  |  |
| 105 | 11.11 | Lawful Interception in the 3GPP Rel-6 architecture | 269d? | 2002-12-09 A | 2003-12-18 | 10% | 242.1d? | 2002-12-09 | 2003-12-18 | 269d? | 649d | finish no earlier than 2003-12-18 | S3 | 2152h | 215.2h | SEC1-LI | 33.106, 33.107, 33.108 | Rel-6 | TSG |  | Berthold Wilhelm | Berthold.Wilhelm@REGTP.DE |  |  |  |
| 106 | 11.12 | IMS Subscription and access scenarios | 130d? | 2002-12-16 A | 2003-06-13 A | 100% |  | 2002-12-16 | 2003-06-13 | 130d? |  | start no earlier than 2002-12-16 | S1 | 1040h | 1040h |  | 22.800 | Rel-6 |  |  |  |  |  |  |  |
| 107 | 11.13 | IMS charging | 455d? | 2003-03-21 A | 2004-12-16 | 90% | 45.5d? |  |  |  | 389d | finish no earlier than 2004-12-16 | S5 | 3640h | 3276h | IMS2-CH | 32.260 | Rel-6 | TSG |  |  |  |  |  |  |
| 108 | 11.14 | Deleted - Stage 2 of IMS Phase 2 | 275d? | 2002-09-02 A | 2003-09-19 | 80% | 55d? |  |  |  | 713d | finish no earlier than 2003-09-19 | S2 | 2200h | 1760h |  |  | Rel-6 |  |  |  |  |  |  | SP-24 |

Notes:
- 77: Not yet available: verbally approved at SA15, actual WID to be provided at SA16 by Lucent
- 78: 29/05/2003 CN4: New WID presented for approval at CN#20...............
- 92: Updated according to SP-040232
- 97: [DAB 14.02.02] - end date pushed back to March 2003
- 98: [DAB - 20.08.03] - CN Part of TR Complete @ CN#20
- 102: [DAB - 25.05.04] - CN3 consider this work to be complete
- 103: [CN4] 17th May 2002, CN4; Will be handled in Rel-6............
- 107: SA#25 09/2004 completed

| ID | WBS | Task | Duration | Start | Finish | Complete | Remaining | Baseline start | Baseline finish | Baseline duration | Total slack | Constraint | Resources | Work | Actual work | Text1 | Text3 | Text4 | Text6 | Text7 | Text8 | Text10 | Text5 | Text2 | Text9 |
| --- | --- | --- | --- | --- | --- | --- | --- | --- | --- | --- | --- | --- | --- | --- | --- | --- | --- | --- | --- | --- | --- | --- | --- | --- | --- |
| 109 | 12 | **3GPP Enablers for services like Push to Talk over Cellular (PoC)** | 465d? | 2003-03-21 A | 2004-12-30 | 80% | 92.56d? | 2003-09-08 | 2004-12-30 | 344d? | 379d |  | S2 | 11608h | 9297.3h | PoC | 23.979 | Shabnam Sultana, Ericsson | R6/R7? | TSG | Sang-Ui |  |  |  |  |
| 110 | 12.1 | Feasibility Study | 322d? | 2003-09-08 A | 2004-11-30 | 87% | 41.86d? | 2003-09-08 | 2004-11-30 | 322d? | 401d | finish no earlier than 2004-11-30 | S2 | 2576h | 2241.12h | PoC | 23.979 | Shabnam Sultana, Ericsson | R6/R7? |  |  | SP-24 |  |  |  |
| 111 | 12.2 | Dependencies on OMA PoC | 261d? | 2004-01-01 A | 2004-12-30 | 75% | 64d? | 2004-01-01 | 2004-12-30 | 261d? | 379d | finish no earlier than 2004-12-30 | OMA | 2088h | 1576h | PoC |  |  | R6/R7? | n/a |  | SP-24 | OMA-LIAISON@mail.openmobilealliance.org |  |  |
| 112 | 12.3 | Selection of one or more PoC codec(s) for PoC | 69d? | 2004-09-13 | 2004-12-16 |  |  |  |  |  | 389d | start no earlier than 2004-09-13 | S4 | 552h |  | PoC |  |  | R6/R7? |  |  | SP-25 |  |  |  |
| 113 | 12.4 | PoC charging | 455d? | 2003-03-21 A | 2004-12-16 | 90% | 45.5d? |  |  |  | 389d | start no earlier than 2003-03-21 | S5 | 3640h | 3276h | CH | 32.272 |  | Rel-6 | TSG |  |  |  |  |  |
| 114 | 13 | Interworking aspects and migration scenarios for IPv4 based IMS Implementations (Study) | 210d? | 2003-09-08 A | 2004-06-25 A | 100% |  | 2003-09-08 | 2004-06-25 | 210d? |  | finish no earlier than 2004-06-25 | S2 | 1680h | 1680h | IPv4IMS | 23.881 | Alexander Milinski, Siemens | Rel-6 |  | Sang-Ui |  |  |  |  |
| 115 | 16.3 | **Interoperability and Commonality between IMS using different "IP-connectivity Networks"** | 325d? | 2002-09-16 A | 2003-12-12 A | 100% |  | 2002-09-16 | 2003-12-12 | 325d? |  |  | S2 | 9176h | 9176h | IMSCOOP | 23.864 |  | Rel-6 | TSG | Sang-Ui |  |  |  |  |
| 116 | 16.3.1 | Stage 2 for Interoperability | 272d | 2002-09-16 A | 2003-09-30 A | 100% |  | 2002-09-16 | 2003-09-30 | 272d |  | finish no earlier than 2003-09-30 | S2 | 2176h | 2176h |  | 23.864 | Balazs Beternyi, Nokia | Rel-6 |  |  |  |  |  |  |
| 117 | 14.2 | Stage 2 for commonality | 265d? | 2002-09-16 A | 2003-09-19 A | 100% |  | 2002-09-16 | 2003-09-19 | 265d? |  | start no earlier than 2002-09-16 | S2 | 2120h | 2120h |  | 23.864 | Balazs Beternyi, Nokia | Rel-6 |  |  |  |  |  |  |
| 118 | 16.3.2 | Stage 3 | 305d | 2002-10-14 A | 2003-12-12 A | 100% |  | 2002-10-14 | 2003-12-12 | 305d |  | finish no earlier than 2003-12-12 | N1 | 2440h | 2440h |  |  | Keith Drage, Lucent | Rel-6 |  |  |  | drage@lucent.com |  |  |
| 119 | 17 | **Support of Push Services** | 823d | 2001-01-03 A | 2004-02-27 | 99% | 0d | 2001-01-03 | 2004-02-27 | 823d | 0d |  | S1 | 11390.6h | 5744h | PUSH | 23.976 | Yoshinori Kitada, NTT Comware | Rel-6 | TSG | Sang-Ui |  |  | CCaR | 1365 |
| 120 | 17.1 | Stage 1 | 378d | 2001-01-03 A | 2002-06-14 A | 100% |  | 2001-01-03 | 2002-06-14 | 378d |  | finish no earlier than 2002-06-14 | S1 | 3024h | 3024h |  |  |  | Rel-6 |  |  |  |  |  |  |
| 121 | 17.3 | TR 23.976 on Push Architecture | 340d | 2002-11-11 A | 2004-02-27 A | 100% |  | 2002-11-11 | 2004-02-27 | 340d |  | finish no earlier than 2004-02-27 | S2 | 2720h | 2720h |  | 23.976 | Nick Alfano, RIM | Rel-6 |  |  |  |  |  |  |
| 122 | 18 | **Multimedia Messaging (MMS) enhancements** | 611d? | 2002-08-15 A | 2004-12-16 | 75% | 152.08d? | 2002-08-15 | 2004-09-16 | 546d? | 389d |  | T2 | 29176h | 22483.3h | MMS6 |  | Josef Laumen, Siemens | Rel-6 | TSG | Friedhelm |  | Josef.Laumen@SAL.SIEMENS.DE | Mes |  |
| 123 | 18.1 | **Definition of service requirements** | 286d? | 2002-11-15 A | 2003-12-19 A | 100% |  | 2002-11-15 | 2003-12-19 | 286d? |  |  | S1 | 4576h | 4576h | MMS6-SR | 22.140 |  | Rel-6 |  |  |  |  |  |  |
| 124 | 16.1.1 | Definition of service requirements charging | 286d? | 2002-11-15 A | 2003-12-19 A | 100% |  | 2002-11-15 | 2003-12-19 | 286d? |  | finish no earlier than 2003-12-20 | S1 | 2288h | 2288h |  | 22.140 | Josef Laumen, Siemens | Rel-6 |  |  |  | Josef.Laumen@SAL.SIEMENS.DE |  |  |
| 125 | 18.2 | Technical realization | 591d | 2002-09-06 A | 2004-12-10 | 80% | 118.2d | 2002-09-06 | 2004-09-10 | 526d | 393d | finish no earlier than 2004-12-10 | T2 | 4728h | 3782.4h |  | 23.140 | Josef Laumen, Siemens | Rel-6 | TSG | Friedhelm |  | Josef.Laumen@SAL.SIEMENS.DE |  |  |
| 126 | 18.3 | OMA dependencies | 346d | 2003-08-15 A | 2004-12-10 | 30% | 242.2d | 2003-08-15 | 2004-08-27 | 228.85d | 393d | finish no earlier than 2004-12-10 | OMA | 2768h | 830.4h |  | OMA specs |  | Rel-6 | n/a | Friedhelm |  |  |  |  |
| 127 | 18.4 | MMS formats and codecs | 611d | 2002-08-15 A | 2004-12-16 | 90% | 61.1d | 2002-08-15 | 2004-09-16 | 546d | 389d | finish no earlier than 2004-12-16 | S4 | 4888h | 4399.2h | MMS6-Codec | 26.140 | Roberto Castagno (Nokia) | Rel-6 |  | Paolo |  | roberto.castagno@nokia.com |  |  |
| 128 | 16.5 | Handling of private addressing schemes in MMS | 263d | 2003-12-10 A | 2004-12-10 | 70% | 78.9d | 2003-12-10 | 2004-06-04 | 128d | 393d | finish no earlier than 2004-12-10 | T2 | 2104h | 1472.8h |  | 23.140 | Matthias Röbke, T-Mobile | Rel-6 | TSG | Friedhelm |  | Matthias.Roebke@t-mobile.de |  |  |
| 129 | 16.6 | FS Multiple MMS Relay/Server Architecture | 263d | 2003-12-10 A | 2004-12-10 | 30% | 184.1d | 2003-12-10 | 2004-06-04 | 128d | 393d | finish no earlier than 2004-12-10 | T2 | 2104h | 631.2h |  | probably Annex to 23.140 | Juan Gorospe, Telefónica Móviles | Rel-6 | TSG | Friedhelm |  | gorospe_j@tsm.es |  |  |
| 130 | 16.7 | MMS charging | 390d? | 2003-03-21 A | 2004-09-16 A | 100% |  |  |  |  |  | start no earlier than 2003-03-21 | S5 | 3120h | 3120h | MMS6-CH | 32.270 |  | Rel-6 | TSG |  |  |  |  |  |
| 131 | 19 | **Rel-6 MExE enhancements** | 326d | 2002-03-08 A | 2003-06-06 A | 100% |  | 2002-03-08 | 2003-06-06 | 326d |  |  | T2 | 7328h | 7328h | MEXE6 |  |  | Rel-6 | TSG | Friedhelm |  |  | Ter |  |
| 132 | 19.1 | MExE Rel-6 Improvements and Investigations | 264d | 2002-03-08 A | 2003-03-12 A | 100% |  | 2002-03-08 | 2003-03-12 | 264d |  | finish no earlier than 2003-03-12 | T2 | 2112h | 2112h | MEXE6-ENHANC | 22.057, 23.057 | Lars Brenk (TTPCom) | Rel-6 | TSG |  |  | lsb_ttpcom@HOTMAIL.COM | Ter |  |
| 133 | 19.2 | MExE Run-Time Independent Framework Feasibility Study | 326d | 2002-03-08 A | 2003-06-06 A | 100% |  | 2002-03-08 | 2003-06-06 | 326d |  | finish no earlier than 2003-06-06 | T2 | 2608h | 2608h | MEXE6-RTIF | 22.857 | Aaron Cohen (Intel) | Rel-6 | TSG |  |  | Aaron.Cohen@intel.com | Ter |  |
| 134 | 21 | Subscription Management | 585d | 2002-09-20 A | 2004-12-16 | 95% | 29.25d | 2002-09-20 | 2004-09-16 | 520d | 389d | finish no earlier than 2004-12-16 | S5 | 4680h | 4446h | SuM | 32.140/1, 32.171/2/3, 32.803 | Istvan ABA (T-Mobile Austria) | Rel-6 | TSG | Adrian |  | istvan.aba@t-mobile.at |  |  |

Notes:
- 111: Updated according to SP-040232
- 113: SA#25 09/2004 completed
- 116: No contributions assumed that no more will be done in 3GPP hence work may need to be done in 3GPP2
- 119: AS: Changed from FS to actual support of Push
- 129: originally it was intended to create a FS TR but most likely the work will become an Annex of 23.140
- 130: SA#25 09/2004 completed
- 134: TSG#25: FOR Approval 32.172, 32.803. Remaining for 12/04 approval 32.173 CORBA SS.

| ID | WBS | Task | Duration | Start | Finish | Complete | Remaining | Baseline start | Baseline finish | Baseline duration | Total slack | Constraint | Resources | Work | Actual work | Text1 | Text4 | Text6 | Text7 | Text8 | Text9 | Text5 | Text3 |
| --- | --- | --- | --- | --- | --- | --- | --- | --- | --- | --- | --- | --- | --- | --- | --- | --- | --- | --- | --- | --- | --- | --- | --- |
| 135 | 22 | **Presence Capability** | 989d? | 2001-03-19 A | 2004-12-30 | 60% | 396.34d? | 2001-03-19 | 2004-12-31 | 990d? | 379d |  | S1 | 32072h | 19219.1h | PRESNC | Mark Cataldo, Motorola | Rel-6 | TSG | Michael | 11004 |  |  |
| 136 | 22.1 | Stage 1 | 610d | 2001-03-19 A | 2003-07-18 A | 100% |  | 2001-03-19 | 2003-07-18 | 610d |  | finish no earlier than 2003-07-18 | S1 | 4880h | 4880h |  |  | Rel-6 |  |  | 11005 |  |  |
| 137 | 22.2 | Stage 2 | 268d | 2001-09-12 A | 2002-09-20 A | 100% |  | 2001-09-12 | 2002-09-20 | 268d |  | finish no earlier than 2002-09-20 | S2 | 2144h | 2144h |  | Balazs BERTENYI, Nokia | Rel-6 | TSG |  |  | Balazs.Bertenyi@nokia.com |  |
| 138 | 22.3 | Stage 3 | 703d | 2002-04-01 A | 2004-12-08 | 91% | 63.27d | 2002-04-01 | 2004-09-08 | 638d | 395d | finish no earlier than 2004-12-08 | N1 | 5624h | 5117.84h |  | Keith Drage, Lucent | Rel-6 |  |  |  | drage@lucent.com |  |
| 139 | 19.4 | Stage 3 (CN3 Part Pk interface) | 703d? | 2002-04-01 | 2004-12-08 |  |  | 2002-04-01 | 2004-09-08 | 638d? | 395d | finish no earlier than 2004-12-08 | N3 | 5624h |  |  |  | Rel-6 |  |  |  |  |  |
| 140 | 19.5 | Media Codecs and Formats for IMS Messaging and Presence | 396d? | 2003-06-12 A | 2004-12-16 | 20% | 316.8d? | 2003-06-12 | 2004-09-16 | 331d? | 389d | finish no earlier than 2004-12-16 | S4 | 3168h | 633.6h | PRESNC-COFIMP | Harri Honko (Nokia) | Rel-6 | TSG | Paolo |  | harri.honko@nokia.com | TS 26.141 |
| 141 | 22.4 | Security issues | 79d | 2002-08-26 A | 2002-12-12 | 20% | 63.2d | 2002-08-26 | 2002-12-12 | 79d | 914d | finish no earlier than 2002-12-12 | S3 | 632h | 126.4h |  |  | Rel-6 |  |  |  |  |  |
| 142 | 19.7 | SIMPLE Presence | 261d? | 2004-01-01 A | 2004-12-30 | 75% | 64d? | 2004-01-01 | 2004-11-30 | 239d? | 379d | finish no earlier than 2004-12-30 | OMA | 2088h | 1576h |  |  | Rel-6 | n/a |  |  | OMA-LIAISON@mail.openmobilealliance.org |  |
| 143 | 25 | **Enhanced A/Gb feasibility study** | 51d? | 2002-08-30 A | 2002-11-08 A | 100% |  | 2002-08-30 | 2002-11-08 | 51d? |  |  | GP | 3264h | 3264h | AGbEnFS | J-L Carrizo, Vodafone | Rel-6 | TSG | Paolo |  | jose-luis.carrizo@vodafone.co.uk |  |
| 144 | 25.1 | **Feasibility study on A/Gb enhancements** | 51d? | 2002-08-30 A | 2002-11-08 A | 100% |  | 2002-08-30 | 2002-11-08 | 51d? |  |  | G2 | 2856h | 2856h | AGbEnFS-FS |  | Rel-6 | TSG |  |  |  |  |
| 145 | 25.1.1 | Requirements for the support of conversational services | 51d | 2002-08-30 A | 2002-11-08 A | 100% |  | 2002-08-30 | 2002-11-08 | 51d |  | finish no earlier than 2002-11-08 | GP | 408h | 408h |  |  | Rel-6 |  |  |  |  |  |
| 146 | 20.1.2 | Identification of the different building blocks for the provision of conversational services on the existing A/Gb protocol stack | 51d? | 2002-08-30 A | 2002-11-08 A | 100% |  | 2002-08-30 | 2002-11-08 | 51d? |  | finish no earlier than 2002-11-08 | GP | 408h | 408h |  |  | Rel-6 |  |  |  |  |  |
| 147 | 20.1.3 | Outline of impact and feasibility of these building blocks and their different solutions | 51d? | 2002-08-30 A | 2002-11-08 A | 100% |  | 2002-08-30 | 2002-11-08 | 51d? |  | finish no earlier than 2002-11-08 | GP | 408h | 408h |  |  | Rel-6 |  |  |  |  |  |
| 148 | 25.1.4 | Impact on 3GPP architecture and requirement to co-ordinatge with other TSGs (CN, SA) | 51d | 2002-08-30 A | 2002-11-08 A | 100% |  | 2002-08-30 | 2002-11-08 | 51d |  | finish no earlier than 2002-11-08 | GP | 408h | 408h |  |  | Rel-6 |  |  |  |  |  |
| 149 | 25.1.5 | Standardisation effort | 51d | 2002-08-30 A | 2002-11-08 A | 100% |  | 2002-08-30 | 2002-11-08 | 51d |  | finish no earlier than 2002-11-08 | GP | 408h | 408h |  |  | Rel-6 |  |  |  |  |  |
| 150 | 25.1.6 | Dependency to other features | 51d | 2002-08-30 A | 2002-11-08 A | 100% |  | 2002-08-30 | 2002-11-08 | 51d |  | finish no earlier than 2002-11-08 | GP | 408h | 408h |  |  | Rel-6 |  |  |  |  |  |
| 151 | 26 | **Flexible Layer One for GERAN** | 1270d | 2000-01-03 A | 2004-11-12 | 93% | 83.34d | 2000-01-03 | 2004-06-25 | 1170d | 413d |  | GP | 81983h | 61035.7h | FLOGER | Benoist Sébire | Rel-6 | TSG | Paolo |  | benoist.sebire@nokia.com |  |
| 152 | 26.1 | **Realisation of a Flexible Layer One** | 1125d | 2000-01-03 A | 2004-04-23 A | 100% |  | 2000-01-03 | 2004-04-23 | 1125d |  |  | GP | 42808h | 42808h | FLOGER-Real | Benoist Sébire | Rel-6 |  |  |  | benoist.sebire@nokia.com |  |
| 153 | 26.1.1 | Technical Report | 471d | 2002-04-19 A | 2004-02-06 A | 100% |  | 2002-04-19 | 2004-02-06 | 471d |  | finish no earlier than 2004-02-06 | GP | 3768h | 3768h |  |  | Rel-6 |  |  |  |  |  |
| 154 | 26.1.2 | Architecture in 45.001 and 43.051 | 526d | 2002-04-19 A | 2004-04-23 A | 100% |  | 2002-04-19 | 2004-04-23 | 526d |  | finish no earlier than 2004-04-23 | G1 | 4208h | 4208h |  |  | Rel-6 |  |  |  |  |  |
| 155 | 26.1.3 | Multiplexing in 45.002 | 526d | 2002-04-19 A | 2004-04-23 A | 100% |  | 2002-04-19 | 2004-04-23 | 526d |  | finish no earlier than 2004-04-23 | G1 | 4208h | 4208h |  |  | Rel-6 |  |  |  |  |  |
| 156 | 26.1.4 | Channel Coding in 45.003 | 526d | 2002-04-19 A | 2004-04-23 A | 100% |  | 2002-04-19 | 2004-04-23 | 526d |  | finish no earlier than 2004-04-23 | G1 | 4208h | 4208h |  |  | Rel-6 |  |  |  |  |  |
| 157 | 26.1.5 | Performance Requirements in 45.005 | 1125d | 2000-01-03 A | 2004-04-23 A | 100% |  | 2000-01-03 | 2004-04-23 | 1125d |  | finish no earlier than 2004-04-23 | G1 | 9000h | 9000h |  |  | Rel-6 |  |  |  |  |  |
| 158 | 26.1.6 | Radio subsystem link control in 45.008 | 526d | 2002-04-19 A | 2004-04-23 A | 100% |  | 2002-04-19 | 2004-04-23 | 526d |  | finish no earlier than 2004-04-23 | G1 | 4208h | 4208h |  |  | Rel-6 |  |  |  |  |  |
| 159 | 26.1.7 | Requirements in 44.004 | 526d | 2002-04-19 A | 2004-04-23 A | 100% |  | 2002-04-19 | 2004-04-23 | 526d |  | finish no earlier than 2004-04-23 | G2 | 4208h | 4208h |  |  | Rel-6 |  |  |  |  |  |

Notes:
- 135: A Sultan merged "Presence Service Enhancements" (UID31028, PRES1) to this feature as no answer was provided on why Presence and Presence Encmts had same target completion date
- 139: No Contributions so far - only requires a little work
- 140: Also for 31022 IMS Messaging
- 141: LSs handled in SA3. WID approved SA#17 Contribution at S3#25 & following e-mail discussion.
- 142: Updated according to SP-040232
- 143: Closed
- 151: Nokia, Ericsson, Siemens, Telia
- 152: Completed

| ID | WBS | Task | Duration | Start | Finish | Complete | Remaining | Baseline start | Baseline finish | Baseline duration | Total slack | Constraint | Resources | Work | Actual work | Text1 | Text4 | Text5 | Text6 | Text3 | Text8 | Text7 | Text9 | Text12 |
| --- | --- | --- | --- | --- | --- | --- | --- | --- | --- | --- | --- | --- | --- | --- | --- | --- | --- | --- | --- | --- | --- | --- | --- | --- |
| 160 | 26.2 | **Signalling and protocol support for a Flexible Layer One** | 571d | 2002-04-19 A | 2004-06-25 | 99% | 0d | 2002-04-19 | 2004-06-25 | 571d | 0d |  | G2 | 13704h | 10134.4h | FLOGER-SigPro | Benoist Sébire | benoist.sebire@nokia.com | Rel-6 |  |  |  |  |  |
| 161 | 26.2.1 | Modifications to RLC/MAC in 44.060 and 44.160 | 571d | 2002-04-19 A | 2004-06-25 A | 100% |  | 2002-04-19 | 2004-06-25 | 571d |  | finish no earlier than 2004-06-25 | G2 | 4568h | 4568h |  |  |  | Rel-6 |  |  |  |  |  |
| 162 | 26.2.2 | Modifications to RRC in 44.118 and 44.018 | 571d | 2002-04-19 A | 2004-06-25 A | 100% |  | 2002-04-19 | 2004-06-25 | 571d |  | finish no earlier than 2004-06-25 | G2 | 4568h | 4568h |  |  |  | Rel-6 |  |  |  |  |  |
| 163 | 26.3 | **Security for a Flexible Layer One** | 356d | 2002-04-19 A | 2003-08-29 A | 100% |  | 2002-04-19 | 2003-08-29 | 356d |  |  | S3, G2 | 5663.04h | 5663.04h | FLOGER-SecFLO | Benoist Sébire | benoist.sebire@nokia.com | Rel-6 |  |  |  |  |  |
| 164 | 26.3.1 | Ciphering in 44.160,44.118, 44.060 and 44.018 | 356d | 2002-04-19 A | 2003-08-29 A | 100% |  | 2002-04-19 | 2003-08-29 | 356d |  | finish no earlier than 2003-08-29 | S3, G2 | 2848h | 2848h |  |  |  | Rel-6 |  |  |  |  |  |
| 165 | 26.4 | **GERAN MS Conformance test for the Flexible Layer One** | 201d | 2004-02-06 | 2004-11-12 |  |  | 2004-02-06 | 2004-06-25 | 101d | 413d |  | G4; G5 | 6432h |  | FLOGER-Msconf | Benoist Sébire | benoist.sebire@nokia.com | Rel-6 |  |  |  |  |  |
| 166 | 26.4.1 | MS Test in 51.010 | 201d | 2004-02-06 | 2004-11-12 |  |  | 2004-02-06 | 2004-06-25 | 101d | 413d | finish no earlier than 2004-11-12 | G4; G5 | 3216h |  |  |  |  | Rel-6 |  |  |  |  |  |
| 167 | 26.5 | **GERAN BTS Conformance test for the Flexible Layer One** | 201d | 2004-02-06 | 2004-11-12 |  |  | 2004-02-06 | 2004-06-25 | 101d | 413d |  | G3 | 3216h |  | FLOGER-BTSconf | Benoist Sébire | benoist.sebire@nokia.com | Rel-6 |  |  |  |  |  |
| 168 | 26.5.1 | BTS Test in 51.021 | 201d | 2004-02-06 | 2004-11-12 |  |  | 2004-02-06 | 2004-06-25 | 101d | 413d | finish no earlier than 2004-11-12 | G3 | 1608h |  |  |  |  | Rel-6 |  |  |  |  |  |
| 169 | 27 | Uplink TDOA feasibility study | 151d | 2001-11-30 A | 2002-06-28 A | 100% |  | 2001-11-30 | 2002-06-28 | 151d |  | finish no earlier than 2002-06-28 | GP | 1208h | 1208h | TDOAF | Bob Gross, TruePosition, Inc. | rlgross@trueposition.com | Rel-6 | 45.811 | Paolo |  |  |  |
| 170 | 28 | **Multimedia Broadcast and Multicast Service** | 1068d? | 2001-05-11 A | 2005-06-15 | 58% | 452.36d? | 2001-05-11 | 2004-12-16 | 940d? | 261d |  | S1 | 120090h | 61679.4h | MBMS |  |  | Rel-6 |  | Michael | TSG |  |  |
| 171 | 28.1 | Stage 1 | 232d | 2001-05-11 A | 2002-04-01 A | 100% |  | 2001-05-11 | 2002-04-01 | 232d |  | finish no earlier than 2002-04-01 | S1 | 1856h | 1856h |  |  |  | Rel-6 | 22.146, 22.101 |  |  | 11003 |  |
| 172 | 28.2 | **Stage 2** | 648d | 2001-09-24 A | 2004-03-17 | 99% | 0d | 2001-09-24 | 2004-03-17 | 648d | 0d |  | S2 | 10408h | 6548.8h |  |  |  | Rel-6 |  |  | TSG |  |  |
| 173 | 28.2.1 | TR on Architectural Study | 240d | 2001-09-24 A | 2002-08-23 A | 100% |  | 2001-09-24 | 2002-08-23 | 240d |  | finish no earlier than 2002-08-23 | S2 | 1920h | 1920h |  |  |  | Rel-6 | 23.846 |  |  |  |  |
| 174 | 28.2.2 | Stage 2 Specification Work | 413d | 2002-08-19 A | 2004-03-17 A | 100% |  | 2002-08-19 | 2004-03-17 | 413d |  | finish no earlier than 2004-03-17 | S2 | 3304h | 3304h |  |  |  | Rel-6 | 23.246 |  |  |  |  |
| 175 | 28.3 | **Introduction of MBMS in RAN** | 901d? | 2002-01-01 A | 2005-06-15 | 64% | 325.7d? | 2002-01-01 | 2004-09-15 | 707d | 261d |  | R2 | 14936h | 9868.8h | MBMS-RAN | Juho Pirskanen , Nokia | juho.pirskanen@nokia.com | Rel-6 | TS 25.346, TS 25.304, 25.321, 25.322, 25.323, 25.331 | MCC_RAN | TSG | 2481 |  |
| 176 | 23.3.1 | Introduction of MBMS in RAN (physical & upper layers, access network interfaces) | 771d? | 2002-01-01 A | 2004-12-14 | 80% | 154.2d? |  |  |  | 391d | finish no earlier than 2004-12-14 | R2 | 6168h | 4934.4h | MBMS-RAN | Juho Pirskanen , Nokia | juho.pirskanen@nokia.com | Rel-6 | TS 25.346, TS 25.304, 25.321, 25.322, 25.323 | MCC_RAN | TSG |  |  |
| 177 | 23.3.2 | UE Performance Requirements for MBMS | 195d? | 2004-09-15 | 2005-06-15 |  |  |  |  |  | 261d | finish no earlier than 2005-06-15 | R4 | 1560h |  | MBMS-RAN-RF | Torgny Palenius, Ericsson | Torgny.Palenius@ericsson.com | Rel-6 | TS25.101, TS25.133 | MCC_RAN | TSG |  |  |
| 178 | 28.4 | Support of the MBMS in CN protocols | 647d | 2002-06-18 A | 2004-12-08 | 90% | 64.7d | 2002-06-18 | 2004-09-08 | 582d | 395d | finish no earlier than 2004-12-08 | N1 | 5176h | 4658.4h |  |  |  | Rel-6 |  |  | TSG |  |  |
| 179 | 23.5 | Gmb interface for MBMS (CN3 part) | 334d | 2003-08-29 A | 2004-12-08 | 85% | 50.1d | 2003-08-29 | 2004-09-10 | 271d | 395d | finish no earlier than 2004-12-08 | N3 | 2672h | 2271.2h |  |  |  | Rel-6 | 29.061 |  |  |  |  |
| 180 | 28.5 | Security Aspects of MBMS | 324d | 2002-07-01 A | 2003-09-25 A | 100% |  | 2002-07-01 | 2003-09-25 | 324d |  | finish no earlier than 2003-09-25 | S3 | 2592h | 2592h | MBMS | Escott, Adrian, 3 | adrian.escott@three.co.uk | Rel-6 |  |  | TSG |  |  |
| 181 | 28.6 | **Support of MBMS in GERAN** | 837d? | 2001-08-30 A | 2004-11-12 | 45% | 461.83d? | 2001-08-30 | 2004-11-12 | 837d? | 413d |  | GP | 65808h | 27617.5h | MBMS-GERAN |  |  | Rel-6 |  |  | TSG |  |  |
| 182 | 28.6.1 | Impact on the logical and physical channels | 576d | 2002-08-30 A | 2004-11-12 | 50% | 288d | 2002-08-30 | 2004-11-12 | 576d | 413d | finish no earlier than 2004-11-12 | GP | 4608h | 2304h |  |  |  | Rel-6 |  |  |  |  |  |
| 183 | 28.6.4 | Re-synchronisation at cell change | 576d | 2002-08-30 A | 2004-11-12 | 50% | 288d | 2002-08-30 | 2004-11-12 | 576d | 413d | finish no earlier than 2004-11-12 | G2 | 4608h | 2304h |  |  |  | Rel-6 |  |  |  |  |  |
| 184 | 23.7.3 | Simultaneous support of MBMS services | 576d? | 2002-08-30 A | 2004-11-12 | 50% | 288d? | 2002-08-30 | 2004-11-12 | 576d? | 413d | finish no earlier than 2004-11-12 | GP | 4608h | 2304h |  |  |  | Rel-6 |  |  |  |  |  |
| 185 | 23.7.4 | Simultaneous support of MBMS and non-MBMS services | 837d? | 2001-08-30 A | 2004-11-12 | 50% | 418.5d? | 2001-08-30 | 2004-11-12 | 837d? | 413d | finish no earlier than 2004-11-12 | GP | 6696h | 3348h |  |  |  | Rel-6 |  |  |  |  |  |
| 186 | 23.7.5 | Resynchronisation at cell change | 837d? | 2001-08-30 A | 2004-11-12 | 50% | 418.5d? | 2001-08-30 | 2004-11-12 | 837d? | 413d | finish no earlier than 2004-11-12 | GP | 6696h | 3348h |  |  |  | Rel-6 |  |  |  |  |  |
| 187 | 28.6.5 | Decision making process between point-to-point or pont-to-multipoint configurations | 576d | 2002-08-30 A | 2004-11-12 | 50% | 288d | 2002-08-30 | 2004-11-12 | 576d | 413d | finish no earlier than 2004-11-12 | GP | 4608h | 2304h |  |  |  | Rel-6 |  |  |  |  |  |
| 188 | 28.6.6 | MBMS channel allocations procedures to multiple MSs | 576d | 2002-08-30 A | 2004-11-12 | 50% | 288d | 2002-08-30 | 2004-11-12 | 576d | 413d | finish no earlier than 2004-11-12 | GP | 4608h | 2304h |  |  |  | Rel-6 |  |  |  |  |  |
| 189 | 28.6.7 | Changes to the Gb interface | 576d | 2002-08-30 A | 2004-11-12 | 50% | 288d | 2002-08-30 | 2004-11-12 | 576d | 413d | finish no earlier than 2004-11-12 | GP | 4608h | 2304h |  |  |  | Rel-6 |  |  |  |  |  |
| 190 | 28.6.8 | GERAN specific changes to the Iu-ps interface | 576d | 2002-08-30 A | 2004-11-12 | 50% | 288d | 2002-08-30 | 2004-11-12 | 576d | 413d | finish no earlier than 2004-11-12 | GP | 4608h | 2304h |  |  |  | Rel-6 |  |  |  |  |  |
| 191 | 28.6.9 | Interaction between MBMS and Iu-flex | 576d | 2002-08-30 A | 2004-11-12 | 50% | 288d | 2002-08-30 | 2004-11-12 | 576d | 413d | finish no earlier than 2004-11-12 | GP | 4608h | 2304h |  |  |  | Rel-6 |  |  |  |  |  |
| 192 | 28.6.10 | Security aspects | 576d | 2002-08-30 A | 2004-11-12 | 50% | 288d | 2002-08-30 | 2004-11-12 | 576d | 413d | finish no earlier than 2004-11-12 | GP | 4608h | 2304h |  |  |  | Rel-6 |  |  |  |  |  |
| 193 | 23.7.12 | MS conformance tests- G3 | 576d? | 2002-08-30 | 2004-11-12 |  |  | 2002-08-30 | 2004-11-12 | 576d? | 413d | finish no earlier than 2004-11-12 | G3 | 4608h |  |  |  |  | Rel-6 |  |  |  |  |  |
| 194 | 23.7.13 | Deleted - MS conformance tests - G5 | 216d? | 2002-08-30 | 2003-06-27 |  |  |  |  |  | 773d | finish no earlier than 2003-06-27 | G5 | 1728h |  |  |  |  | Rel-6 |  |  |  |  | GP-19 |

Notes:
- 160: Completed
- 163: Started
- 165: Not started
- 167: Not started
- 170: Title renamed at SA#13
- 171: This may or may not be a separate stage 1. In the meantime, CRs are proposed for 22.101
- 176: Was "Introduction of MBMS in RAN" before RP#25. Created w/o WIDS after RAN approved the WT for RF aspects.Take WIDS from the parent BB
- 177: Approved at RP#25 as RP-040370
- 180: WID approved SA#17

| ID | WBS | Task | Duration | Start | Finish | Complete | Remaining | Baseline start | Baseline finish | Baseline duration | Total slack | Constraint | Resources | Work | Actual work | Text3 | Text6 | Text8 | Text9 | Text1 | Text4 | Text5 | Text7 | Text10 | Text12 |
| --- | --- | --- | --- | --- | --- | --- | --- | --- | --- | --- | --- | --- | --- | --- | --- | --- | --- | --- | --- | --- | --- | --- | --- | --- | --- |
| 195 | 28.1 | **MBMS User Services** | 418d? | 2003-05-13 A | 2004-12-16 | 75% | 105.26d? | 2003-05-13 | 2004-12-16 | 418d? | 389d |  | S1 | 8376h | 6266.69h | 22.246 | Rel-6 | Michael | 11003 |  |  |  |  |  |  |
| 196 | 28.1 | MBMS User Services Stage 1 | 233d | 2003-05-13 A | 2004-04-01 A | 100% |  | 2003-05-13 | 2004-04-01 | 233d |  | start no earlier than 2003-05-13 | S1 | 1864h | 1864h | 22.246 | Rel-6 | Michael | 11003 |  |  |  |  |  |  |
| 197 | 23.8.2 | Definition of MBMS user services, media codecs, formats and transport/application protocols using MBMS | 396d? | 2003-06-12 A | 2004-12-16 | 60% | 158.4d? | 2003-06-12 | 2004-12-16 | 396d? | 389d | finish no earlier than 2004-12-16 | S4 | 3168h | 1900.8h | 26.346 | Rel-6 | Paolo |  | MBMS-TSMBMS | Igor Curcio (Nokia) | igor.curcio@nokia.com | TSG |  |  |
| 198 | 29 | **Speech Recognition and Speech Enabled Services** | 974d? | 2001-10-08 A | 2005-06-30 | 71% | 283.38d? | 2001-10-08 | 2004-06-10 | 699d? | 249d |  | S1 | 19544h | 13857.8h |  | Rel-6 | Michael |  | SRSES |  |  | TSG |  |  |
| 199 | 29.1 | Speech Enabled Services Based on Distributed Speech Recognition (DSR) | 115d | 2001-10-08 A | 2002-03-15 A | 100% |  | 2001-10-08 | 2002-03-15 | 115d |  | finish no earlier than 2002-03-15 | S1 | 920h | 920h | 22.941, 23.207, 22.243 | Rel-6 |  |  | DSR | D Williams, QUALCOMM, Inc. | Dwilliams@qualcomm.com | TSG |  |  |
| 200 | 29.2 | TR on Architectural impacts | 212d | 2003-05-12 A | 2004-03-02 A | 100% |  | 2003-05-12 | 2004-03-02 | 212d |  | finish no earlier than 2004-03-02 | S2 | 1696h | 1696h | 23.877 | Rel-6 |  |  |  |  |  |  |  |  |
| 201 | 24.3 | Codec Work to Support Speech Recognition Framework for Automated Voice Services | 568d? | 2002-10-15 A | 2004-12-16 | 95% | 28.4d? | 2002-10-15 | 2004-06-10 | 433d? | 389d | finish no earlier than 2004-12-16 | S4 | 4544h | 4316.8h | 26.235, 26.236, 26.243 | Rel-6 | Paolo |  | SRSES-Codec | David Pearce, Motorola | bdp003@motorola.com | WG |  |  |
| 202 | 24.4 | Multimodal support | 391d? | 2004-01-01 A | 2005-06-30 | 45% | 216d? | 2004-01-01 | 2004-01-01 | 1d? | 249d | finish no earlier than 2005-06-30 | OMA | 3128h | 1400h |  | Rel-6 |  |  |  |  | OMA-LIAISON@mail.openmobilealliance.org |  | SP-24 |  |
| 203 | 24.5 | Deleted - SES codec negotiation at SDP | 183d? | 2002-09-23 | 2003-06-04 |  |  |  |  |  | 790d | finish no earlier than 2003-06-04 | N1 | 1464h |  |  | Rel-6 |  |  |  |  |  |  |  | NP-23 |
| 204 | 30 | **Generic User Profile** | 889d | 2001-10-08 A | 2005-03-03 | 55% | 397.28d | 2001-10-08 | 2004-11-30 | 822d | 334d |  | S1 | 28983.8h | 16031.4h |  | Rel-6 | Michael |  | GUP |  |  | TSG |  |  |
| 205 | 30.1 | Stage 1 - Requirements | 430d | 2001-10-08 A | 2003-05-30 A | 100% |  | 2001-10-08 | 2003-05-30 | 430d |  | finish no earlier than 2002-12-09 | S1 | 3440h | 3440h | 22.240, 22.228 | Rel-6 |  |  |  | Paul Amery (Orange) | paul.amery@orange.co.uk |  |  |  |
| 206 | 30.3 | Stage 2 - Architecture | 355d | 2002-01-28 A | 2003-06-06 A | 100% |  | 2002-01-28 | 2003-06-06 | 355d |  | finish no earlier than 2003-06-06 | S2 | 2840h | 2840h | 23.240 | Rel-6 |  |  |  | Harri KOSKINEN, Nokia | harri.o.koskinen@nokia.com |  |  |  |
| 207 | 30.2 | Stage 2 - Data Description Method | 586d | 2002-12-05 A | 2005-03-03 | 45% | 322.3d | 2002-12-05 | 2004-03-05 | 327d | 334d | finish no earlier than 2005-03-03 | N4 | 4688h | 2109.6h | 23.241 | Rel-6 | Friedhelm |  |  | Kurt Bischinger (T-Mobile AUSTRIA) | kurt.bischinger@t-mobile.at | TSG |  |  |
| 208 | 30.4 | Stage 3 - Common objects | 586d | 2002-12-05 A | 2005-03-03 | 40% | 351.6d | 2002-12-05 | 2004-09-03 | 457d | 334d | finish no earlier than 2005-03-03 | N4 | 4688h | 1875.2h | 24.241 | Rel-6 | Friedhelm |  |  |  |  | TSG |  |  |
| 209 | 30.5 | Stage 3 - Network | 468.98d | 2003-05-19 A | 2005-03-03 | 39% | 286.08d | 2003-05-19 | 2004-11-30 | 401.98d | 334d | finish no earlier than 2005-03-03 | N4 | 3751.84h | 1463.22h | 29.240 | Rel-6 |  |  |  |  |  |  |  |  |
| 210 | 30.6 | Security Aspects | 308d | 2002-07-16 A | 2003-09-18 | 15% | 261.8d | 2002-07-16 | 2003-09-18 | 308d | 714d | finish no earlier than 2003-09-18 | S3 | 2464h | 369.6h | 33.102, 33.203, 33.210 | Rel-6 |  |  |  | Owen, Bradley | bvowen@lucent.com | WG |  |  |
| 211 | 31 | **Digital Rights Management** | 690d? | 2001-10-08 A | 2004-05-28 | 75% | 174.85d? | 2001-10-08 | 2004-05-28 | 690d? | 533d |  | S1 | 11392h | 8505.2h |  | Rel-6 | Michael |  | DRM |  |  | TSG |  |  |
| 212 | 31.1 | Requirements | 179d | 2001-10-08 A | 2002-06-13 A | 100% |  | 2001-10-08 | 2002-06-13 | 179d |  | finish no earlier than 2002-06-13 | S1 | 1432h | 1432h |  | Rel-6 |  |  |  | Nicholas Wood, Openwave Systems | nicholas.wood@openwave.com |  |  |  |
| 213 | 26.2 | Deleted - Monitoring of Stages 2 and 3 progress (actual work to be done by OMA) | 155d? | 2002-08-19 A | 2003-03-21 A | 100% |  | 2002-08-19 | 2003-03-21 | 155d? |  | start no earlier than 2002-08-19 | S1 | 1240h | 1240h |  | Rel-6 |  |  |  |  |  |  |  |  |
| 214 | 26.3 | Stage 2 | 107d? | 2004-01-01 A | 2004-05-28 A | 100% |  | 2004-01-01 | 2004-05-28 | 107d? |  | finish no earlier than 2004-05-28 | OMA | 856h | 856h |  | Rel-6 |  |  |  |  | OMA-LIAISON@mail.openmobilealliance.org |  | SP-24 |  |
| 215 | 26.4 | Stage 3 | 107d? | 2004-01-01 A | 2004-05-28 A | 100% |  | 2004-01-01 | 2004-05-28 | 107d? |  | finish no earlier than 2004-05-28 | OMA | 856h | 856h |  | Rel-6 |  |  |  |  | OMA-LIAISON@mail.openmobilealliance.org |  | SP-24 |  |
| 216 | 31.3 | Security | 186d | 2002-03-04 | 2003-03-03 |  |  | 2002-06-17 | 2003-03-03 | 186d | 857d | finish no earlier than 2003-03-03 | OMA | 1488h |  |  | Rel-6 |  |  |  |  |  |  |  |  |
| 217 | 32 | **WLAN-UMTS Interworking** | 1359d? | 2000-01-03 A | 2005-03-17 | 87% | 172.31d? | 2000-01-03 | 2004-09-30 | 1239d? | 324d |  | S1 | 44096h | 38621.7h |  | Rel-6 | Michael |  | WLAN | Fredric Paint, Telenor | frederic.paint@telenor.com | TSG |  |  |
| 218 | 32.1 | Technical Report | 900d? | 2000-01-03 A | 2003-06-13 A | 100% |  | 2000-01-03 | 2003-06-13 | 900d? |  | finish no earlier than 2003-06-13 | S1 | 7200h | 7200h | 22.934, 22.101, 22.105 | Rel-6 |  |  | WLAN-TR | Fredric Paint, Telenor | frederic.paint@telenor.com |  |  |  |

Notes:
- 203: Abandoned NP-23
- 209: 17 May no activity in CN4............
- 210: WID approved SA#17. SA WG3 progress slow, depends on progress in other groups.
- 211: Foreseen start and completion dates introduced by MCC (no indication at all on the WID)
- 213: Replaced by UID 60005 and 60006
- 216: SA3 acknowledge role in WI at SA3#20. Active contribution S3#24, S3#25. S3 WID approved SA#17

| ID | WBS | Task | Duration | Start | Finish | Complete | Remaining | Baseline start | Baseline finish | Baseline duration | Total slack | Constraint | Resources | Work | Actual work | Text1 | Text3 | Text4 | Text5 | Text6 | Text10 | Text7 | Text8 | Text9 | Text11 |
| --- | --- | --- | --- | --- | --- | --- | --- | --- | --- | --- | --- | --- | --- | --- | --- | --- | --- | --- | --- | --- | --- | --- | --- | --- | --- |
| 219 | 27.2 | **Stage 1** | 375d? | 2003-01-06 A | 2004-06-11 | 83% | 64.48d? | 2000-01-03 | 2004-06-11 | 1160d? | 523d |  | S1 | 4840h | 4166h | WLAN-TS | 22.234 | Fredric Paint, Telenor | frederic.paint@telenor.com | Rel-6 | SP-24 |  |  |  |  |
| 220 | 27.2.1 | Global stage 1 | 375d? | 2003-01-06 A | 2004-06-11 | 99% | 3.75d? |  |  |  | 523d | finish no earlier than 2004-06-11 | S1 | 3000h | 2970h | WLAN-TS | 22.234 | Fredric Paint, Telenor | frederic.paint@telenor.com | Rel-6 | SP-24 |  |  |  |  |
| 221 | 27.2.2 | Session Continuity | 115d? | 2004-01-05 A | 2004-06-11 | 30% | 80.5d? |  |  |  | 523d | start no earlier than 2004-01-05 | S1 | 920h | 276h | WLAN-SC |  |  |  | Rel-7 | SP-24 |  |  |  |  |
| 222 | 32.2 | Architecture Definition for scenarii 2 and 3 | 571d | 2002-03-25 A | 2004-05-31 A | 100% |  | 2002-03-25 | 2004-05-31 | 571d |  | finish no earlier than 2004-05-31 | S2 | 4568h | 4568h |  | 23.234 |  |  | Rel-6 |  | TSG |  |  |  |
| 223 | 32.3 | Security | 125d | 2002-09-30 A | 2003-03-21 | 30% | 87.5d | 2002-09-30 | 2003-03-21 | 125d | 843d | finish no earlier than 2003-03-21 | S3 | 1000h | 300h |  | 21.133, 33.106, 33.107, 33.108, 33.200, 33.203, 33.210 | Lopez-Soria, Luis, Ericsson | luis.lopez-soria@ece.ericsson.se | Rel-6 |  | TSG |  |  |  |
| 224 | 27.5 | Stage 3 - CN4 aspects | 334d? | 2003-05-23 A | 2004-09-01 | 85% | 50.1d? | 2003-05-23 | 2004-09-01 | 334d? | 465d | finish no earlier than 2004-09-01 | N4 | 2672h | 2271.2h | WLAN-IW | 29.234, 29.061 | Rodriguez ,Raquel, Nokia | raquel.rodriguez@nokia.com | Rel-6 |  | TSG |  |  |  |
| 225 | 27.6 | Stage 3 - CN3 aspects (Wi Interface for Scenario 3) | 355d? | 2003-05-23 A | 2004-09-30 | 95% | 17.75d? | 2003-05-23 | 2004-09-30 | 355d? | 444d | start no earlier than 2003-05-23 | N3 | 2840h | 2698h | WLAN | 29.161 |  |  | Rel-6 | SP-24 | TSG |  |  |  |
| 226 | 27.7 | Stage 3 for scenario 2 | 339d? | 2003-05-23 A | 2004-09-08 | 98% | 6.78d? | 2003-05-23 | 2004-09-08 | 339d? | 460d | finish no earlier than 2004-09-08 | N1 | 2712h | 2657.76h |  |  |  |  | Rel-6 |  | WG |  |  |  |
| 227 | 27.8 | Stage 3 for scenario 3 | 404d? | 2003-05-23 A | 2004-12-08 | 60% | 161.6d? | 2003-05-23 | 2004-09-08 | 339d? | 395d | finish no earlier than 2004-12-08 | N1 | 3232h | 1939.2h |  |  |  |  | Rel-6 | SP-24 | WG |  |  |  |
| 228 | 27.9 | WLAN charging | 520d? | 2003-03-21 A | 2005-03-17 | 80% | 104d? |  |  |  | 324d | start no earlier than 2003-03-21 | S5 | 4160h | 3328h | WLAN-CH | 32.252 |  |  | Rel-6 |  | TSG |  |  |  |
| 229 | 33 | **Priority Service** | 666d? | 2002-05-30 A | 2004-12-16 | 76% | 162.53d? | 2002-05-30 | 2004-12-16 | 666d? | 389d |  | S1 | 12616h | 9537.26h | NTShar |  |  |  | Rel-6 |  | TSG | Michael |  |  |
| 230 | 33.1 | Feasibility Study | 1d | 2002-06-14 A | 2002-06-14 A | 100% |  | 2002-06-14 | 2002-06-14 | 1d |  | finish no earlier than 2002-06-14 | S1 | 8h | 8h | PRIOR-FS | 22.950 | Biplab K. Pramanik, Telcordia Technologies | bpramani@telcordia.com | Rel-6 |  |  | Michael |  |  |
| 231 | 33.2 | Stage 1 - Requirements | 340d | 2002-05-30 A | 2003-09-17 A | 100% |  | 2002-05-30 | 2003-09-17 | 340d |  | finish no earlier than 2003-09-17 | S1 | 2720h | 2720h | PRIOR-SR |  | James J. Garrahan, Telcordia Technologies | bpramani@telcordia.com | Rel-6 |  |  | Michael |  |  |
| 232 | 28.3 | Multimedia Priority Service | 450d? | 2003-03-28 A | 2004-12-16 | 50% | 225d? | 2003-03-28 | 2004-12-16 | 450d? | 389d | finish no earlier than 2004-12-16 | S1 | 3600h | 1800h |  |  |  |  | Rel-6 |  |  |  |  |  |
| 233 | 28.4 | Priority service implementation guide | 131d? | 2003-03-28 A | 2003-09-26 A | 100% |  | 2003-03-28 | 2003-09-26 | 131d? |  | finish no earlier than 2003-09-26 | S1 | 1048h | 1048h |  | 22.952 | Biplab K. Pramanik, Telcordia Technologies | bpramani@telcordia.com | Rel-6 |  |  |  |  |  |
| 234 | 34 | **Network Sharing** | 498d? | 2003-01-20 A | 2004-12-15 | 94% | 28.05d? | 2003-01-20 | 2005-03-17 | 563.41d? | 390d |  | S1 | 16608h | 15672.5h | NTShar |  |  |  | Rel-6 |  | TSG | Michael |  |  |
| 235 | 34.1 | Technical Report | 240d? | 2003-01-20 A | 2003-12-19 A | 100% |  | 2003-01-20 | 2003-12-19 | 240d? |  |  | S1 | 1920h | 1920h | NTShar-TR | 22.951 |  |  | Rel-6 |  |  | Michael |  |  |
| 236 | 29.2 | Stage 1 - CRs to implement Network Sharing | 240d? | 2003-01-20 A | 2003-12-19 A | 100% |  | 2003-01-20 | 2003-12-19 | 240d? |  | finish no earlier than 2003-12-19 | S1 | 1920h | 1920h | NTShar-CR | 22.011, 22.101, 22.115, 22.129 |  |  | Rel-6 |  |  |  |  |  |
| 237 | 29.3 | Stage 2 | 372d? | 2003-02-27 A | 2004-07-30 A | 100% |  | 2003-02-27 | 2004-07-30 | 372d? |  | finish no earlier than 2004-07-30 | S2 | 2976h | 2976h |  | 23.251 |  |  | Rel-6 |  |  |  |  |  |
| 238 | 29.4 | Network sharing - stage 3 | 404d? | 2003-05-23 A | 2004-12-08 | 90% | 40.4d? | 2003-05-23 | 2004-09-08 | 339d? | 395d | finish no earlier than 2004-12-08 | N1 | 3232h | 2908.8h |  |  |  |  | Rel-6 |  | TSG |  |  |  |
| 239 | 29.5 | Enhancement of the support of network sharing in the UTRAN | 324d | 2003-09-19 A | 2004-12-15 | 85% | 48.6d | 2003-09-19 | 2005-03-17 | 389.41d | 390d | finish no earlier than 2004-12-15 | R2 | 2592h | 2203.2h | NTShar-UTRANEnh | TS25.401, TS25.413, TS25.331, TS25.304 | Anders Dahlén, TeliaSonera | Anders.Dahlen@TeliaSonera.com | Rel-6 |  | TSG | MCC_RAN | BB | Active |
| 240 | 35 | **QoS Improvements** | 628d? | 2002-07-15 A | 2004-12-08 | 95% | 31.06d? | 2002-07-15 | 2004-09-10 | 565d? | 395d |  | S2 | 13128h | 12478.7h | QoS1 |  |  |  | Rel-6 |  | TSG | Sang-Ui |  |  |
| 241 | 35.1 | FS on Dynamic Policy control enhancements for end-to-end QoS | 465d | 2002-07-15 A | 2004-04-23 A | 100% |  | 2002-07-15 | 2004-04-23 | 465d |  | finish no earlier than 2004-04-23 | S2 | 3720h | 3720h | QoS1 | 23.917 |  | Claire Mousset, Nortel | Rel-6 |  | TSG |  |  |  |
| 242 | 30.2 | Definition of the Gq interface | 214d? | 2003-07-01 A | 2004-04-23 A | 100% |  | 2003-07-01 | 2004-04-23 | 214d? |  | finish no earlier than 2004-04-23 | S2 | 1712h | 1712h |  | 23.221 | Janne Rinne (Nokia) |  | Rel-6 |  |  |  |  |  |
| 243 | 30.3 | Gq interface specification for Dynamic Policy control enhancements – Stage 3 | 334d | 2003-08-29 A | 2004-12-08 | 85% | 50.1d | 2003-08-29 | 2004-09-10 | 271d | 395d | finish no earlier than 2004-12-08 | N3 | 2672h | 2271.2h |  | 24,228, 29.207, 29.208 | Anna Sillanpää, Nokia | Anna.Sillanpaai@nokia.com | Rel-6 |  | TSG |  |  |  |

Notes:
- 223: Active contribution S3#24, S3#25. WID approved SA#17
- 224: WID approved at CN#19...............
- 228: SA#25 09/2004 completed
- 243: [DAB - 25.05.04] - Delayed to Sept - possibly Dec 2004

| ID | WBS | Task | Duration | Start | Finish | Complete | Remaining | Baseline start | Baseline finish | Baseline duration | Total slack | Constraint | Resources | Work | Actual work | Text1 | Text4 | Text5 | Text6 | Text7 | Text8 | Text10 | Text12 |
| --- | --- | --- | --- | --- | --- | --- | --- | --- | --- | --- | --- | --- | --- | --- | --- | --- | --- | --- | --- | --- | --- | --- | --- |
| 244 | 36 | **Subscriber certificates** | 728d? | 2002-02-25 A | 2004-12-08 | 80% | 145.56d? | 2002-02-25 | 2004-11-30 | 722d? | 395d |  | S3 | 12888h | 10311.1h | SEC1-SC | Valtteri Niemi, Nokia | valtteri.niemi@nokia.com | Rel-6 | TSG | Maurice |  |  |
| 245 | 36.1 | Stage 1 | 144d | 2002-02-25 A | 2002-09-12 | 40% | 86.4d | 2002-02-25 | 2002-09-12 | 144d | 979d | finish no earlier than 2002-09-12 | S3 | 1152h | 460.8h |  |  |  | Rel-6 |  |  |  |  |
| 246 | 36.2 | Architecture review | 24d | 2002-10-14 A | 2002-11-14 A | 100% |  | 2002-10-14 | 2002-11-14 | 24d |  | finish no earlier than 2002-11-14 | S2 | 192h | 192h |  |  |  | Rel-6 |  |  |  |  |
| 247 | 31.3 | Stage 3 | 313d? | 2003-09-19 A | 2004-11-30 | 85% | 46.95d? | 2003-09-19 | 2004-11-30 | 313d? | 401d | finish no earlier than 2004-11-30 | N4 | 2504h | 2128.4h | SEC1-SC | Lauri Laitinen, Nokia |  | Rel-6 |  | Kimmo |  |  |
| 248 | 31.4 | Stage 3 Ua & Ub interfaces | 288d? | 2003-11-03 A | 2004-12-08 | 85% | 43.2d? | 2003-11-03 | 2004-09-08 | 223d? | 395d | finish no earlier than 2004-12-08 | N1 | 2304h | 1958.4h |  |  |  | Rel-6 |  |  |  |  |
| 249 | 31.5 | OMA dependencies on Subscriber certificates | 114d? | 2004-01-01 A | 2004-06-08 A | 100% |  | 2004-01-01 | 2004-06-08 | 114d? |  | finish no earlier than 2004-06-08 | OMA | 912h | 912h |  |  | OMA-LIAISON@mail.openmobilealliance.org | Rel-6 | n/a |  | SP-24 |  |
| 250 | 32 | **Rel-6 OSA enhancements** | 552d? | 2002-10-31 A | 2004-12-10 | 82% | 101.02d? | 2002-10-31 | 2004-09-30 | 501d? | 393d |  | S1 | 26783.2h | 19636.3h | OSA3 | Chelo ABARCA (Alcatel) | Chelo.Abarca@alcatel.fr | Rel-6 | TSG | Adrian |  |  |
| 251 | 32.1 | Scope of the Open Service Access Release 6 | 66d? | 2003-03-28 A | 2003-06-27 A | 100% |  | 2003-03-28 | 2003-06-27 | 66d? |  | finish no earlier than 2003-06-27 | S1 | 528h | 528h |  |  |  | Rel-6 | TSG |  |  |  |
| 252 | 32.2 | OSA Stage 2 | 86d? | 2004-08-13 A | 2004-12-10 | 75% | 21.5d? |  |  |  | 393d | finish no earlier than 2004-12-10 | N5 | 688h | 516h |  |  |  | Rel-6 | TSG |  |  |  |
| 253 | 32.3 | Multi Media Messaging function | 487d? | 2002-10-31 A | 2004-09-10 A | 100% |  | 2002-10-31 | 2004-06-18 | 427d? |  | finish no earlier than 2004-09-10 | N5 | 3896h | 3896h |  |  |  | Rel-6 | TSG |  |  |  |
| 254 | 32.4 | Policy management extensions | 292d? | 2002-10-31 A | 2003-12-12 A | 100% |  | 2002-10-31 | 2003-12-12 | 292d? |  | finish no earlier than 2003-12-12 | N5 | 2336h | 2336h |  |  |  | Rel-6 | TSG |  |  |  |
| 255 | 32.5 | TS on Presence and Availability Management (from the PRESNC WI) | 367d? | 2002-10-31 A | 2004-03-26 A | 100% |  | 2002-10-31 | 2004-03-26 | 367d? |  | finish no earlier than 2004-03-26 | N5 | 2936h | 2936h |  |  |  | Rel-6 | TSG |  |  |  |
| 256 | 32.6 | OSA interfaces at different levels of abstractions (Parlay X, Web services) | 305d? | 2003-07-14 A | 2004-09-10 A | 100% |  | 2003-07-14 | 2004-06-18 | 245d? |  | finish no earlier than 2004-09-10 | N5 | 2440h | 2440h |  |  |  | Rel-6 | TSG |  |  |  |
| 257 | 32.7 | Introduction of migration support mechanism | 290d? | 2002-10-31 A | 2003-12-10 A | 100% |  | 2002-10-31 | 2003-12-10 | 290d? |  | finish no earlier than 2003-12-12 | N5 | 2320h | 2320h |  |  |  | Rel-6 | TSG |  |  |  |
| 258 | 32.8 | Framework Function for Federation | 225d? | 2003-02-03 A | 2003-12-12 A | 100% |  | 2003-02-03 | 2003-12-12 | 225d? |  | finish no earlier than 2003-12-12 | N5 | 1800h | 1800h |  |  |  | Rel-6 | TSG |  |  |  |
| 259 | 32.9 | OMA potential overlaps with 3GPP OSA Stage 3 (Web services) | 196d? | 2003-12-18 A | 2004-09-16 A | 100% |  | 2004-01-01 | 2004-09-30 | 196d? |  | start no earlier than 2003-12-18 | OMA | 1568h | 1568h |  |  |  | Rel-6 | n/a |  | SP-24 |  |
| 260 | 32.10 | Deleted - TR on Presence and Availability Management (from the PRESNC WI) | 492d? | 2002-10-31 | 2004-09-17 |  |  |  |  |  | 453d | finish no earlier than 2004-09-17 | N5 | 3936h |  |  |  |  | Rel-6 |  |  |  | NP-24 |
| 261 | 39 | **Addition of frequency bands to GSM** | 621d | 2002-06-28 A | 2004-11-12 | 4% | 596.04d | 2002-06-28 | 2004-11-12 | 621d | 413d |  | GP | 15320h | 615.64h | TAPS | Torben Themsen |  | Rel-6 | TSG | Paolo |  |  |
| 262 | 39.1 | **Addition of frequency bands to GSM – Changes to core specs** | 26d | 2002-11-15 A | 2002-12-20 A | 100% |  | 2002-11-15 | 2002-12-20 | 26d |  |  | G1 | 416h | 416h | TAPS-Specs | Torben Themsen |  | Rel-6 | TSG |  |  |  |
| 263 | 39.1.1 | Changes to core specs | 26d | 2002-11-15 A | 2002-12-20 A | 100% |  | 2002-11-15 | 2002-12-20 | 26d |  | finish no earlier than 2002-12-20 | G1 | 208h | 208h |  |  |  | Rel-6 |  |  |  |  |
| 264 | 39.2 | **Addition of frequency bands to GSM – Changes for conformance tests** | 621d | 2002-06-28 | 2004-11-12 |  |  | 2002-06-28 | 2004-11-12 | 621d | 413d |  | G4 | 9936h |  | TAPS-Conf | Torben Themsen |  | Rel-6 |  |  |  |  |
| 265 | 39.2.1 | 51.010-1 Add testing | 621d | 2002-06-28 | 2004-11-12 |  |  | 2002-06-28 | 2004-11-12 | 621d | 413d | finish no earlier than 2004-11-12 | G4 | 4968h |  |  |  |  | Rel-6 |  |  |  |  |
| 266 | 40 | **Seamless support of streaming services in A/Gb mode** | 1065d? | 2000-01-03 A | 2004-01-30 | 94% | 68.97d? | 2000-01-03 | 2004-01-30 | 1065d? | 618d |  | GP | 40840h | 37411.7h | SSStrea | José Luis Carrizo Martínez, Vodafone |  | Rel-6 | TSG | Paolo |  |  |
| 267 | 40.1 | **Identification of requirements for streaming** | 46d? | 2003-06-27 A | 2003-08-29 A | 100% |  | 2003-06-27 | 2003-08-29 | 46d? |  |  | G1 | 736h | 736h |  |  |  | Rel-6 |  |  |  |  |
| 268 | 34.1.1 | Requirements | 46d? | 2003-06-27 A | 2003-08-29 A | 100% |  | 2003-06-27 | 2003-08-29 | 46d? |  | finish no earlier than 2003-08-29 | G1 | 368h | 368h |  |  |  | Rel-6 |  |  |  |  |

Notes:
- 244: Approved at SA#14. This may require BBs from CN1, CN4, SA5 and T3 / Text3: 33.102
- 245: Contribution received S3#24, S3#25
- 247: WID approved at CN#21............
- 249: Updated according to SP-040420
- 250: CN#25: Updated WID NP-040351 replaces NP-040144. / Text3: 22.127, 23.198, 29.198, 29.199, 29.998
- 252: Task inherited by CN5 from SA2 at TSG#25. 23.127 (OSA/VHE Stage 2) to be replaced from Rel-6 onwards by a new TS 23.198 Stage 2 OSA-only in 12/04 / Text3: 23.198 OSA Stage 2-ONLY replaces 23.127 (OSA/VHE) from Rel-6 onwards
- 253: CN#25: TSG Approved. Completed. / Text3: 29.198-15
- 254: Text3: 29.198, 29.998
- 255: N5#26: Split WI into TS & TR. / Text3: 29.198-14
- 256: CN#25: TSG Approved. Completed. / Text3: 29.199
- 257: Text3: 29.198, 29.998
- 258: Text3: 29.198, 29.998
- 259: TSG#25 Approved CN5 29.199 Parlay X Web services. Ongoing 3GPP/OMA co-ordination to avoid OMA producing conflicting/OVERLAPING specs (NP-040283/SP-040493).
- 260: N5#26:TR Completion 09/04; consistent with CN1 delayed Rel-6 completion.
- 262: Ready
- 264: Not started
- 267: Started

| ID | WBS | Task | Duration | Start | Finish | Complete | Remaining | Baseline start | Baseline finish | Baseline duration | Total slack | Constraint | Resources | Work | Actual work | Text6 | Text3 | Text4 | Text5 | Text1 | Text7 | Text8 | Text2 |
| --- | --- | --- | --- | --- | --- | --- | --- | --- | --- | --- | --- | --- | --- | --- | --- | --- | --- | --- | --- | --- | --- | --- | --- |
| 269 | 40.2 | **Performance study of cell change mechanisms** | 955d? | 2000-01-03 A | 2003-08-29 A | 100% |  | 2000-01-03 | 2003-08-29 | 955d? |  |  | G1 | 30560h | 30560h | Rel-6 |  |  |  |  |  |  |  |
| 270 | 34.2.1 | Performance of NACC | 955d? | 2000-01-03 A | 2003-08-29 A | 100% |  | 2000-01-03 | 2003-08-29 | 955d? |  | finish no earlier than 2003-08-29 | G1 | 7640h | 7640h | Rel-6 |  |  |  |  |  |  |  |
| 271 | 34.2.2 | Performance of cell change in DTM for the PS domain | 955d? | 2000-01-03 A | 2003-08-29 A | 100% |  | 2000-01-03 | 2003-08-29 | 955d? |  | finish no earlier than 2003-08-29 | G1 | 7640h | 7640h | Rel-6 |  |  |  |  |  |  |  |
| 272 | 34.2.3 | Handover | 955d? | 2000-01-03 A | 2003-08-29 A | 100% |  | 2000-01-03 | 2003-08-29 | 955d? |  | finish no earlier than 2003-08-29 | G1 | 7640h | 7640h | Rel-6 |  |  |  |  |  |  |  |
| 273 | 40.3 | **Reduction of service interruption times and packet loss during mobility procedures** | 106d? | 2003-06-27 A | 2003-11-21 | 99% | 0d? | 2003-06-27 | 2003-11-21 | 106d? | 0d |  | G2 | 4240h | 3396h | Rel-6 |  |  |  |  |  |  |  |
| 274 | 34.3.1 | Optimisations of existing mechanisms/procedures | 106d? | 2003-06-27 A | 2003-11-21 A | 100% |  | 2003-06-27 | 2003-11-21 | 106d? |  | finish no earlier than 2003-11-21 | G2 | 848h | 848h | Rel-6 |  |  |  |  |  |  |  |
| 275 | 34.3.2 | Inter-system NACC | 106d? | 2003-06-27 A | 2003-11-21 A | 100% |  | 2003-06-27 | 2003-11-21 | 106d? |  | finish no earlier than 2003-11-21 | G2 | 848h | 848h | Rel-6 |  |  |  |  |  |  |  |
| 276 | 34.3.3 | PS Handover (within GERAN and between GERAN and UTRAN) | 106d? | 2003-06-27 A | 2003-11-21 A | 100% |  | 2003-06-27 | 2003-11-21 | 106d? |  | finish no earlier than 2003-11-21 | G2 | 848h | 848h | Rel-6 |  |  |  |  |  |  |  |
| 277 | 34.3.4 | Dependency to other features | 106d? | 2003-06-27 A | 2003-11-21 A | 100% |  | 2003-06-27 | 2003-11-21 | 106d? |  | finish no earlier than 2003-11-21 | G2 | 848h | 848h | Rel-6 |  |  |  |  |  |  |  |
| 278 | 40.5 | **MS conformance testing** | 31d? | 2003-12-19 A | 2004-01-30 A | 100% |  | 2003-12-19 | 2004-01-30 | 31d? |  |  | G3 | 248h | 248h | Rel-6 |  |  |  |  |  |  |  |
| 279 | 34.4.1 | MS conformance tests | 31d? | 2003-12-19 A | 2004-01-30 A | 100% |  | 2003-12-19 | 2004-01-30 | 31d? |  | finish no earlier than 2004-01-30 | G4,G5 | 248h | 248h | Rel-6 |  |  |  |  |  |  |  |
| 280 | 34.5 | GERAN A/Gb mode security enhancements | 261d? | 2002-09-26 A | 2003-09-25 | 10% | 234.9d? | 2002-09-26 | 2003-09-25 | 261d? | 709d | finish no earlier than 2003-09-25 | S3 | 2088h | 208.8h | Rel-6 | 33.102 | Peter Howard, Vodafone | peter.howard@vodafone.com |  |  |  |  |
| 281 | 41 | Performance characterisation of default codecs for PS conversational multimedia application | 455d | 2002-09-13 A | 2004-06-10 A | 100% |  | 2002-09-13 | 2004-06-10 | 455d |  | finish no earlier than 2004-06-10 | S4 | 3640h | 3640h | Rel-6 | TR 26.935 | Pasi Ojala (Nokia) | pasi.s.ojala@nokia.com | CODCAR | TSG | Paolo |  |
| 282 | 43 | Study on Privacy Capability | 83d | 2003-11-10 A | 2004-03-03 | 85% | 12.45d | 2003-11-10 | 2004-03-03 | 83d | 595d | start no earlier than 2003-11-10 | S1 | 664h | 564.4h | Rel-6 | TR 21.xyz | Liz Daniel, Lucent |  | PrivCap | TSG | Michael |  |
| 283 | 44 | **OAM&P** | 715d? | 2002-09-12 A | 2005-06-08 | 84% | 116.28d? | 2002-09-12 | 2004-12-08 | 585d? | 265d |  | S5 | 34083.5h | 23810.6h | Rel-6 | 32-series | Michael TRUSS (Motorola) | Michael.Truss@MOTOROLA.COM | OAM | TSG | Adrian |  |
| 284 | 44.1 | Principles, high level Requirements and Architecture | 526d | 2002-09-12 A | 2004-09-16 A | 100% |  | 2002-09-12 | 2004-09-16 | 526d |  | finish no earlier than 2004-09-16 | S5 | 4208h | 4208h | Rel-6 | 32.101, 32.102 | Michael TRUSS (Motorola) | Michael.Truss@MOTOROLA.COM | OAM-AR | TSG |  | BCaM |
| 285 | 44.2 | Performance Management | 591d | 2002-09-12 A | 2004-12-16 | 95% | 29.55d | 2002-09-12 | 2004-09-16 | 526d | 389d | finish no earlier than 2004-12-16 | S5 | 4728h | 4491.6h | Rel-6 | 32.401/3, 52.402, 32.411/2/3, 32.432/5/6 | Christian TOCHE (Nortel Networks) | toche@NORTELNETWORKS.COM | OAM-PM | TSG |  | BCaM |
| 286 | 44.4 | Network Infrastructure Management | 591d | 2002-09-12 A | 2004-12-16 | 95% | 29.55d | 2002-09-12 | 2004-09-16 | 526d | 389d | finish no earlier than 2004-12-16 | S5 | 4728h | 4491.6h | Rel-6 | 32.15x, 32.3/6/7xy | Thomas TOVINGER (Ericsson) | Thomas.Tovinger@emw.ericsson.se | OAM-NIM | TSG |  |  |
| 287 | 44.5 | **Trace Management** | 709d? | 2002-09-20 A | 2005-06-08 | 67% | 231.98d? | 2002-09-20 | 2004-12-08 | 579d? | 265d |  | S5 | 14821.9h | 7547.05h |  | 32.42x, 52.008 | Kari RÖNKÄ (Nokia) | kari.t.ronka@nokia.com | OAM-Trace | TSG |  |  |
| 288 | 37.4.1 | Subscriber and UE trace management | 585d | 2002-09-20 A | 2004-12-16 | 95% | 29.25d | 2002-09-20 | 2004-09-16 | 520d | 389d | finish no earlier than 2004-12-16 | S5 | 4680h | 4446h |  | 32.421/2/3, 52.008 | Kari RÖNKÄ (Nokia) | kari.t.ronka@nokia.com | OAM-Trace | TSG |  |  |
| 289 | 37.4.2 | Subscriber and equipment trace in UTRAN | 268d? | 2003-06-06 A | 2004-06-15 A | 100% |  | 2003-06-06 | 2004-06-15 | 268d? |  | finish no earlier than 2004-06-15 | R3 | 2144h | 2144h |  | TS25.413, 25.420, 25.423 | Yann Sehedi, Nortel | sehedic@nortelnetworks.com | OAM-Trace-RAN | TSG | MCC_RAN |  |
| 290 | 37.4.3 | SIP enhancements for trace | 343d? | 2004-02-16 A | 2005-06-08 | 2% | 336.14d? | 2004-02-16 | 2004-12-08 | 213d? | 265d | finish no earlier than 2005-06-08 | N1 | 2744h | 54.88h |  |  |  |  |  |  |  |  |
| 291 | 37.4.4 | Trace Management, Stage3 | 132.74d? | 2004-06-09 A | 2004-12-16 | 48% | 69.37d? | 2004-02-16 | 2004-12-08 | 213d? | 389d | finish no earlier than 2004-12-16 | N4 | 1061.93h | 506.97h |  | TS 23.205, 29.232, 29.060, 29.002, 29.228 | Seppo Kauntola ( Nokia Corporation) | seppo.kauntola@nokia.com | OAM-Trace |  |  |  |
| 292 | 38 | **Charging Management** | 541d? | 2002-11-21 A | 2004-12-16 | 86% | 74.16d? | 2002-11-21 | 2004-09-16 | 476d? | 389d |  | S5 | 51248h | 40812.9h | Rel-6 | 32.2xy | Karl-Heinz NENNER (T-Mobile) | karl-heinz.nenner@t-mobile.de | CH | TSG | Adrian |  |
| 293 | 38.1 | Charging architecture and principles | 390d? | 2003-03-21 A | 2004-09-16 A | 100% |  |  |  |  |  | start no earlier than 2003-03-21 | S5 | 3120h | 3120h | Rel-6 | 32.240 |  |  | CH | TSG |  |  |
| 294 | 38.2 | Charging Data Record (CDR) file format and transfer | 260d? | 2003-03-21 A | 2004-03-18 A | 100% |  |  |  |  |  | start no earlier than 2003-03-21 | S5 | 2080h | 2080h | Rel-6 | 32.297 |  |  | CH | TSG |  |  |
| 295 | 38.3 | CDR parameter description | 455d? | 2003-03-21 A | 2004-12-16 | 70% | 136.5d? |  |  |  | 389d | start no earlier than 2003-03-21 | S5 | 3640h | 2548h | Rel-6 | 32.298 |  |  | CH | TSG |  |  |
| 296 | 38.4 | Diameter charging applications | 390d? | 2003-03-21 A | 2004-09-16 A | 100% |  |  |  |  |  | start no earlier than 2003-03-21 | S5 | 3120h | 3120h | Rel-6 | 32.299 |  |  | CH | TSG |  |  |
| 297 | 38.5 | Online Charging System (OCS) architecture study | 130d? | 2003-03-21 A | 2003-09-18 A | 100% |  |  |  |  |  | start no earlier than 2003-03-21 | S5 | 1040h | 1040h | Rel-6 | 32.815 |  |  | CH | TSG |  |  |
| 298 | 38.6 | OCS: Applications and interfaces | 455d? | 2003-03-21 A | 2004-12-16 | 70% | 136.5d? |  |  |  | 389d | start no earlier than 2003-03-21 | S5 | 3640h | 2548h | Rel-6 | 32.296 |  |  | CH | TSG |  |  |

Notes:
- 269: Started
- 273: Completed at GERAN#17
- 278: Closed, no work needed
- 279: Closed, no work needed
- 280: Possible changes to 33.102 or new specification needed.
- 283: SA#24: Completionl delayed 09/04->12/04 due to OAM-Trace.
- 284: SA#24: Completed
- 285: TSG#25: for Info 32.432/5/6 => Approval 12/04. Withdrawn from Rel-6 32.431/3/4.
- 287: TSG#25: SA5 completion 12/04 depending on CN1/CN4 input. CN1 cannot complete 24.229 trace without IETF dependency => estimate 05/05.
- 288: TSG#25: for Info 32.423/52.008, for Approval 32.422.
- 292: TSG#25 For Approval 32.240/51/7095/99. For Info 32.296. Approval 12/04 32.260/71/96/98. Date uncertain WLAN/PoC Charging 32.252/72 (Reason: SA2/OMA dependencies).
- 293: SA#25 09/2004 completed
- 294: SA#23 03/2004 completed
- 295: Target SA#26 12/2004 completed
- 296: SA#25 09/2004 completed
- 297: SA#21 09/2003 completed
- 298: Target SA#26 12/2004 completed

| ID | WBS | Task | Duration | Start | Finish | Complete | Remaining | Baseline start | Baseline finish | Baseline duration | Total slack | Constraint | Resources | Work | Actual work | Text1 | Text4 | Text6 | Text7 | Text10 | Text5 | Text2 | Text8 | Text9 |
| --- | --- | --- | --- | --- | --- | --- | --- | --- | --- | --- | --- | --- | --- | --- | --- | --- | --- | --- | --- | --- | --- | --- | --- | --- |
| 299 | 38.7 | **Charging Management for Bearer level** | 390d? | 2003-03-21 A | 2004-09-16 A | 100% |  | 2003-03-21 | 2004-09-16 | 390d? |  |  | S5 | 11440h | 11440h | CH-BC | Benni ALEXANDER (Nokia) | Rel-6 | TSG |  |  |  |  |  |
| 300 | 38.7.1 | CS domain charging | 260d? | 2003-03-21 A | 2004-03-18 A | 100% |  |  |  |  |  | start no earlier than 2003-03-21 | S5 | 2080h | 2080h | CH |  | Rel-6 | TSG |  |  |  |  |  |
| 301 | 38.7.2 | PS domain charging | 390d? | 2003-03-21 A | 2004-09-16 A | 100% |  |  |  |  |  | start no earlier than 2003-03-21 | S5 | 3120h | 3120h | CH |  | Rel-6 | TSG |  |  |  |  |  |
| 302 | 38.7.3 | CDR transfer | 390d? | 2003-03-21 A | 2004-09-16 A | 100% |  |  |  |  |  | start no earlier than 2003-03-21 | S5 | 3120h | 3120h | CH |  | Rel-6 | TSG |  |  |  |  |  |
| 303 | 38.8 | Charging Management for the IMS | 455d? | 2003-03-21 A | 2004-12-16 | 90% | 45.5d? | 2003-03-21 | 2004-09-16 | 390d? | 389d | finish no earlier than 2004-12-16 | S5 | 3640h | 3276h | IMS2-CH | Patrik TEPPO (Ericsson) | Rel-6 | TSG |  |  |  |  |  |
| 304 | 38.9 | Charging Management for the Service domain | 455d? | 2003-03-21 A | 2004-12-16 | 90% | 45.5d? | 2003-03-21 | 2004-09-16 | 390d? | 389d | finish no earlier than 2004-12-16 | S5 | 3640h | 3276h | CH | Gerald GÖRMER (Siemens) | Rel-6 | TSG |  |  |  |  |  |
| 305 | 38.10 | **Overall architectural aspects of IP flow based bearer level charging** | 535d? | 2002-11-21 A | 2004-12-08 | 66% | 184.13d? | 2002-11-21 | 2004-07-30 | 442d? | 395d |  | S2 | 11560h | 6751.68h | CH-FBC |  | Rel-6 |  |  |  |  |  |  |
| 306 | 38.10.1 | Overall definition of FBC architecture | 334d? | 2002-11-21 A | 2004-03-02 | 99% | 1d? | 2002-11-21 | 2004-03-02 | 334d? | 596d | start no earlier than 2002-11-21 | S2 | 2672h | 2664h |  |  | Rel-6 |  | SP-24 |  |  |  |  |
| 307 | 38.10.2 | Study on providing policy control with FBC | 130d? | 2004-02-02 A | 2004-07-30 A | 100% |  | 2004-02-02 | 2004-07-30 | 130d? |  | start no earlier than 2004-02-01 | S2 | 1040h | 1040h |  |  | Rel-6 |  | SP-24 |  |  |  |  |
| 308 | 38.10.3 | Gx interface for flow based charging | 223d? | 2004-02-02 A | 2004-12-08 | 50% | 111.5d? | 2004-02-02 | 2004-07-30 | 130d? | 395d | start no earlier than 2004-02-01 | N3 | 1784h | 892h |  |  | Rel-6 |  | SP-25 |  |  |  |  |
| 309 | 38.10.4 | Rx interface for flow based charging | 223d? | 2004-02-02 A | 2004-12-08 | 10% | 200.7d? | 2004-02-02 | 2004-07-30 | 130d? | 395d | start no earlier than 2004-02-01 | N3 | 1784h | 178.4h |  | Javier Gonzalez Gallego | Rel-6 |  | SP-25 | ggfj@nortelnetworks.com |  |  |  |
| 310 | 13 | **Rel-6 UICC/USIM enhancements and interworking** | 1164d | 2000-09-25 A | 2005-03-10 | 74% | 300.39d | 2000-09-25 | 2004-02-19 | 889d | 329d |  | T3 | 35312h | 27307.3h | USAT1 |  | Rel-6 | TSG |  |  | Ter | Claus | 1800 |
| 311 | 13.1 | **UICC API** | 777d | 2002-03-20 A | 2005-03-10 | 57% | 332.97d | 2002-03-20 | 2004-02-19 | 502d | 329d |  | T3 | 14936h | 8535.44h | USAT1-API |  | Rel-6 |  |  |  | Ter |  | 1802 |
| 312 | 13.1.1 | Java API Test specification | 59d | 2002-03-20 A | 2002-06-10 A | 100% |  | 2002-03-20 | 2002-06-10 | 59d |  | finish no earlier than 2002-09-20 | T3 | 472h | 472h |  | Mario Pérez (Microelectrónica Española) | Rel-6 |  |  |  |  |  |  |
| 313 | 13.1.2 | Java API Test specification (TS 43.019 Rel-5) | 268d | 2002-05-30 A | 2003-06-09 A | 100% |  | 2002-05-30 | 2003-06-09 | 268d |  | finish no earlier than 2003-09-17 | T3 | 2144h | 2144h |  | Mario Pérez (Microelectrónica Española) | Rel-6 |  |  |  |  |  |  |
| 314 | 39.1.3 | 2G/3G Java Card™ API based applet interworking | 244d | 2003-03-17 A | 2004-02-19 A | 100% |  | 2003-03-17 | 2004-02-19 | 244d |  | finish no earlier than 2004-02-19 | T3 | 1952h | 1952h | USAT1-API | Stéphane Andrau-Oberthur Card Systems | Rel-6 | TSG |  |  |  |  |  |
| 315 | 39.1.4 | (U)SIM API for Java Card Testing Work Item | 519d | 2003-03-17 A | 2005-03-10 | 10% | 467.1d | 2003-03-17 | 2004-02-19 | 244d | 329d | finish no earlier than 2005-03-10 | T3 | 4152h | 415.2h |  | Christophe Begassat (Axalto) | Rel-6 | TSG |  | 'cbegassat@axalto.com' |  | Friedhelm |  |
| 316 | 39.2 | **Rel-6 USIM toolkit enhancements** | 525d | 2000-09-25 A | 2002-09-27 A | 100% |  | 2000-09-25 | 2002-09-27 | 525d |  |  | T3 | 14160h | 14160h |  |  | Rel-6 |  |  |  |  | Claus |  |
| 317 | 39.2.1 | **C SIM API** | 525d | 2000-09-25 A | 2002-09-27 A | 100% |  | 2000-09-25 | 2002-09-27 | 525d |  |  | T3 | 9960h | 9960h | USAT1-API-MULTOS |  | Rel-6 | TSG |  |  | Ter |  | 2031 |
| 318 | 39.2.1.1 | Specification | 525d | 2000-09-25 A | 2002-09-27 A | 100% |  | 2000-09-25 | 2002-09-27 | 525d |  | finish no earlier than 2002-09-27 | T3 | 4200h | 4200h |  | Neil Livingston – Aspects Software | Rel-6 | TSG |  |  | Ter |  | 2032 |
| 319 | 39.2.1.2 | Test specification | 195d | 2001-01-01 A | 2001-09-28 A | 100% |  | 2001-01-01 | 2001-09-28 | 195d |  | finish no earlier than 2001-09-28 | T3 | 1560h | 1560h |  | Neil Livingston – Aspects Software | Rel-6 | TSG |  |  | Ter |  | 2033 |
| 320 | 40 | **Packet Switched Streaming Services Rel-6** | 544d? | 2002-11-18 A | 2004-12-16 | 91% | 46.74d? | 2002-11-18 | 2004-09-16 | 479d? | 389d |  | S4 | 9240h | 8446.06h | PSSrel6 | Olle Franceschi (Ericsson) | Rel-6 | TSG |  | olle.franceschi@ericsson.com |  | Paolo |  |
| 321 | 40.1 | Stage 1 | 86d? | 2002-11-18 A | 2003-03-17 A | 100% |  | 2002-11-18 | 2003-03-17 | 86d? |  | finish no earlier than 2003-03-17 | S1 | 688h | 688h |  |  | Rel-6 | TSG |  |  |  |  |  |
| 322 | 40.2 | Stage 3 | 525d? | 2002-12-13 A | 2004-12-16 | 90% | 52.5d? | 2002-12-13 | 2004-09-16 | 460d? | 389d | finish no earlier than 2004-12-16 | S4 | 4200h | 3780h | PSSrel6-Stage3 | Olle Franceschi (Ericsson) | Rel-6 | WG |  | olle.franceschi@ericsson.com |  | Paolo |  |
| 323 | 41 | AMR-WB extension for high audio quality | 525d | 2002-12-13 A | 2004-12-16 | 95% | 26.25d | 2002-12-13 | 2004-06-10 | 390d | 389d | finish no earlier than 2004-12-16 | S4 | 4200h | 3990h | AMRWB+ | Janne Vainio (Nokia) | Rel-6 | TSG |  | janne.m.vainio@nokia.com |  | Paolo |  |
| 324 | 42 | Codec Enhancements for Packet Switched Conversational Multimedia Applications | 198d? | 2004-03-16 A | 2004-12-16 | 80% | 39.6d? | 2004-03-16 | 2004-09-16 | 133d? | 389d | finish no earlier than 2004-12-16 | S4 | 1584h | 1267.2h | CEPSCM | Miska Hannuksela (Nokia) | Rel-6 | WG |  | miska.hannuksela@nokia.com |  | Paolo |  |
| 325 | 43 | 3G-324M Improvements | 198d? | 2004-03-16 A | 2004-12-16 | 80% | 39.6d? | 2004-03-16 | 2004-09-16 | 133d? | 389d | finish no earlier than 2004-12-16 | S4 | 1584h | 1267.2h | 3G-324MI | Bo Burman, Ericsson | Rel-6 | WG |  | bo.burman@ericsson.com |  | Paolo |  |
| 326 | 44 | Single Antenna Receiver Interference Cancellation (SAIC) | 420.92d? | 2002-11-15 A | 2004-08-27 | 90% | 42.09d? | 2002-11-15 | 2004-06-25 | 375.92d? | 468d | finish no earlier than 2004-08-27 | GP; G1 | 6734.72h | 6061.25h | SAIC | Marc Grant, Cingular Wireless | Rel-6 | TSG |  |  |  | Paolo |  |

Notes:
- 300: SA#23 03/2004 completed / Text3: 32.250
- 301: SA#25 09/2004 completed / Text3: 32.251
- 302: SA#25 09/2004 completed / Text3: 32.295
- 303: Text3: 32.260
- 304: Text3: 32.252, 32.270/1/2
- 305: Text3: 23.125
- 308: Text3: 29.210
- 309: Text3: 29.209
- 311: 8/3/2001: test spec is based on R99 core spec, so deleted from Workplan
- 315: Text3: 31.213
- 321: 2nd resp SA4 / Text3: 22.233
- 322: Completed except SVG Tiny 1.2 / Text3: 26.233, 26.234, 26.244, 26.245, 26.246, 26.401, 26.402, 26.403, 26.404, 26.405, 26.410
- 323: Text3: 26.290, 26.304
- 324: Text3: 26.235, 26.236
- 325: Text3: 26.111, 26.911

| ID | WBS | Task | Duration | Start | Finish | Complete | Remaining | Baseline start | Baseline finish | Baseline duration | Total slack | Constraint | Resources | Work | Actual work | Text1 | Text4 | Text5 | Text6 | Text7 | Text8 | Text3 |
| --- | --- | --- | --- | --- | --- | --- | --- | --- | --- | --- | --- | --- | --- | --- | --- | --- | --- | --- | --- | --- | --- | --- |
| 327 | 45 | **Support of Conversational Services in A/Gb mode via the PS domain** | 406d? | 2003-02-07 A | 2004-08-27 | 28% | 292.78d? | 2003-02-07 | 2004-08-27 | 406d? | 468d |  | GP | 13512h | 2258.93h | SCSAGB | David Bladsjö, Ericsson | david.bladsjo@ericsson.com | Rel-6 | TSG | Paolo |  |
| 328 | 45.1 | Creation of a TR | 206d? | 2003-02-07 A | 2003-11-21 A | 100% |  | 2003-02-07 | 2003-11-21 | 206d? |  | finish no earlier than 2003-11-21 | GP | 1648h | 1648h | SCSAGB-TR | David Bladsjö, Ericsson |  | Rel-6 | TSG |  |  |
| 329 | 45.2 | Stage 2 | 201d? | 2003-11-21 A | 2004-08-27 | 35% | 130.65d? | 2003-11-21 | 2004-08-27 | 201d? | 468d | finish no earlier than 2004-08-27 | GP | 1608h | 562.8h | SCSAGB-Stage2 | David Bladsjö, Ericsson |  | Rel-6 | TSG |  |  |
| 330 | 45.3 | Radio Channel Support | 146d? | 2004-02-06 | 2004-08-27 |  |  | 2004-02-06 | 2004-08-27 | 146d? | 468d | finish no earlier than 2004-08-27 | GP | 1168h |  | SCSAGB-RCS | David Bladsjö, Ericsson |  | Rel-6 | TSG |  |  |
| 331 | 45.4 | Definition of radio resource management functionality | 146d? | 2004-02-06 | 2004-08-27 |  |  | 2004-02-06 | 2004-08-27 | 146d? | 468d | finish no earlier than 2004-08-27 | GP; G2 | 2336h |  | SCSAGB-RRM | David Bladsjö, Ericsson |  | Rel-6 | TSG |  |  |
| 332 | 45.5 | PS Handover | 146d? | 2004-02-06 | 2004-08-27 |  |  | 2004-02-06 | 2004-08-27 | 146d? | 468d | finish no earlier than 2004-08-27 | GP | 1168h |  | SCSAGB-PSH | David Bladsjö, Ericsson |  | Rel-6 | TSG |  |  |
| 333 | 45.6 | Modifications to FLO | 146d? | 2004-02-06 | 2004-08-27 |  |  | 2004-02-06 | 2004-08-27 | 146d? | 468d | finish no earlier than 2004-08-27 | GP; G2 | 2336h |  | SCSAGB-FLO | David Bladsjö, Ericsson |  | Rel-6 | TSG |  |  |
| 334 | 46 | **Enhancement of dialled service for CAMEL** | 199d | 2003-03-28 A | 2003-12-31 A | 100% |  | 2003-03-28 | 2003-12-31 | 199d |  |  | S1 | 3184h | 3184h | EDCAMEL | Craig Bishop, Samsung Electronics Research Institute |  | Rel-6 | TSG | Andrijana |  |
| 335 | 46.1 | Stages 2 and 3 | 199d | 2003-03-28 A | 2003-12-31 A | 100% |  | 2003-03-28 | 2003-12-31 | 199d |  | finish no earlier than 2003-09-19 | N4 | 1592h | 1592h |  |  |  | Rel-6 |  |  |  |
| 336 | 47 | Bandwidth and resource savings in CS networks | 273d? | 2003-06-01 A | 2004-06-16 A | 100% |  | 2003-06-01 | 2004-06-16 | 273d? |  | finish no earlier than 2004-06-16 | S2 | 2184h | 2184h | BARS |  |  | Rel-6 |  | Sang-Ui | 23.977 |
| 337 | 48 | FS on (U)SIM Security Reuse by Peripheral Devices on Local Interfaces | 127d? | 2003-07-03 A | 2003-12-26 | 5% | 120.65d? | 2003-07-03 | 2003-12-26 | 127d? | 643d | finish no earlier than 2003-12-26 | S3 | 1016h | 50.8h |  | Raziq Yaqub, Toshiba America Research Inc. | ryaqub@tari.toshiba.com | Rel-6 | TSG | Maurice |  |
| 338 | 49 | **Multiple TBF in A/Gb mode** | 581d? | 2002-04-05 A | 2004-06-25 | 65% | 201.05d? | 2002-04-05 | 2004-06-25 | 581d? | 513d |  | GP; G2 | 37368h | 27408.6h | MULTBF | Gunnar Mildh, Ericsson |  | Rel-6 | TSG | Paolo |  |
| 339 | 49.1 | **Multiple TBF in A/Gb mode** | 366d? | 2002-04-05 A | 2003-08-29 A | 100% |  | 2002-04-05 | 2003-08-29 | 366d? |  |  | GP; G2 | 23424h | 23424h | MULTBF-Agbmode | Gunnar Mildh, Ericsson |  | Rel-6 | TSG |  |  |
| 340 | 49.1.1 | Multiple TBF Concept paper | 366d? | 2002-04-05 A | 2003-08-29 A | 100% |  | 2002-04-05 | 2003-08-29 | 366d? |  | finish no earlier than 2003-08-29 | GP; G2 | 5856h | 5856h |  |  |  | Rel-6 |  |  |  |
| 341 | 49.1.2 | Multiple TBF Stage 2 (43.064) CRs | 366d? | 2002-04-05 A | 2003-08-29 A | 100% |  | 2002-04-05 | 2003-08-29 | 366d? |  | finish no earlier than 2003-08-29 | GP; G2 | 5856h | 5856h |  |  |  | Rel-6 |  |  |  |
| 342 | 49.1.3 | Multiple TBF Stage 3 (44.060) CRs | 366d? | 2002-04-05 A | 2003-08-29 A | 100% |  | 2002-04-05 | 2003-08-29 | 366d? |  | finish no earlier than 2003-08-29 | GP; G2 | 5856h | 5856h |  |  |  | Rel-6 |  |  |  |
| 343 | 49.2 | Multiple TBF in A/Gb mode – MS testing | 581d? | 2002-04-05 | 2004-06-25 |  |  | 2002-04-05 | 2004-06-25 | 581d? | 513d | finish no earlier than 2004-06-25 | G3 | 4648h |  | MULTBF-Testing | Gunnar Mildh, Ericsson |  | Rel-6 | TSG | Paolo |  |
| 344 | 50 | **Alignment between the test-regimes for GERAN capable MS** | 261d? | 2003-08-29 A | 2004-08-27 | 80% | 52.2d? | 2003-08-29 | 2004-08-27 | 261d? | 468d |  | G3 | 4176h | 1670.4h | ALTERE | Toubassi, Ericsson |  | Rel-6 | TSG | Michael |  |
| 345 | 50.1 | Determine the controversial test cases in the different test regimes and align them with 3GPP GERAN test specifications. Such test cases to be added to TS 51.010. | 261d? | 2003-08-29 A | 2004-08-27 | 80% | 52.2d? | 2003-08-29 | 2004-08-27 | 261d? | 468d | finish no earlier than 2004-08-27 | G3 | 2088h | 1670.4h | ALTERE-TC |  |  | Rel-6 | TSG |  |  |
| 346 | 51 | Addition of U-TDOA in the CS domain | 111d? | 2003-11-21 A | 2004-04-23 A | 100% |  | 2003-11-21 | 2004-04-23 | 111d? |  | finish no earlier than 2004-04-23 | GP | 888h | 888h | UTDOACS | Bob Gross, Rhys Robinson, TruePosition, Inc. | rlgross@trueposition.com | Rel-6 | TSG | Paolo |  |
| 347 | 52 | Addition of U-TDOA in the PS domain | 361d? | 2003-06-27 A | 2004-11-12 | 5% | 342.95d? | 2003-06-27 | 2004-11-12 | 361d? | 413d | finish no earlier than 2004-11-12 | GP | 2888h | 144.4h | UTDOAPS | Bob Gross, Rhys Robinson, TruePosition, Inc. | rlgross@trueposition.com | Rel-6 | TSG | Paolo |  |
| 348 | 53 | **Downlink Advanced Receiver Performance** | 332d? | 2003-11-21 A | 2005-02-28 | 27% | 243.94d? | 2003-11-21 | 2005-02-28 | 332d? | 337d |  | GP | 16576h | 2872.53h | DARP | Tommy Bysted, Nokia | tommy.bysted@nokia.com | Rel-6 | TSG | Paolo |  |
| 349 | 53.1 | DARP test scenarios | 201d? | 2003-11-21 A | 2004-08-27 | 45% | 110.55d? | 2003-11-21 | 2004-08-27 | 201d? | 468d | finish no earlier than 2004-08-27 | GP | 1608h | 723.6h | DARP-TS | Tommy Bysted, Nokia | tommy.bysted@nokia.com | Rel-6 | TSG | Paolo |  |
| 350 | 53.2 | **DARP for GMSK modulated voice services** | 201d? | 2004-02-06 A | 2004-11-12 | 15% | 170.85d? | 2004-02-06 | 2004-11-12 | 201d? | 413d |  | GP | 4824h | 482.4h | DARP-GMSK | Tommy Bysted, Nokia | tommy.bysted@nokia.com | Rel-6 | TSG | Paolo |  |
| 351 | 53.2.1 | Performance requirements in 45.005 | 201d? | 2004-02-06 A | 2004-11-12 | 15% | 170.85d? | 2004-02-06 | 2004-11-12 | 201d? | 413d | finish no earlier than 2004-11-12 | GP | 1608h | 241.2h | DARP-GMSK-Perf |  |  | Rel-6 | TSG |  |  |
| 352 | 53.2.2 | Radio subsystem link control in 45.008 | 201d? | 2004-02-06 A | 2004-11-12 | 15% | 170.85d? | 2004-02-06 | 2004-11-12 | 201d? | 413d | finish no earlier than 2004-11-12 | GP | 1608h | 241.2h | DARP-GMSK-LC |  |  | Rel-6 | TSG |  |  |

Notes:
- 329: Started
- 330: Not started
- 331: Not started
- 332: Not started
- 333: Not started
- 337: Approved TSG#20
- 342: Not started
- 343: Not started
- 345: Started
- 346: Completed, except for potential LMU performance specs
- 347: Started
- 349: Started
- 350: Started
- 351: Started
- 352: Started

| ID | WBS | Task | Duration | Start | Finish | Complete | Remaining | Baseline start | Baseline finish | Baseline duration | Total slack | Constraint | Resources | Work | Actual work | Text1 | Text4 | Text5 | Text6 | Text7 | Text8 | Text3 | Text10 | Text9 |
| --- | --- | --- | --- | --- | --- | --- | --- | --- | --- | --- | --- | --- | --- | --- | --- | --- | --- | --- | --- | --- | --- | --- | --- | --- |
| 353 | 53.3 | **DARP for GPRS and EGPRS MCS1-MCS4** | 201d? | 2004-02-06 A | 2004-11-12 | 10% | 180.9d? | 2004-02-06 | 2004-11-12 | 201d? | 413d |  | GP | 4824h | 321.6h | DARP-GPRSE | Tommy Bysted, Nokia | tommy.bysted@nokia.com | Rel-6 | TSG | Paolo |  |  |  |
| 354 | 53.3.1 | Performance requirements in 45.005 | 201d? | 2004-02-06 A | 2004-11-12 | 10% | 180.9d? | 2004-02-06 | 2004-11-12 | 201d? | 413d | finish no earlier than 2004-11-12 | GP | 1608h | 160.8h | DARP-GPRSE-Perf |  |  | Rel-6 | TSG |  |  |  |  |
| 355 | 53.3.2 | Radio subsystem link control in 45.008 | 201d? | 2004-02-06 A | 2004-11-12 | 10% | 180.9d? | 2004-02-06 | 2004-11-12 | 201d? | 413d | finish no earlier than 2004-11-12 | GP | 1608h | 160.8h | DARP-GPRSE-LC |  |  | Rel-6 | TSG |  |  |  |  |
| 356 | 53.4 | DARP Capability signalling | 201d? | 2003-11-21 A | 2004-08-27 | 75% | 50.25d? | 2003-11-21 | 2004-06-25 | 156d? | 468d | finish no earlier than 2004-08-27 | GP | 1608h | 1206h | DARP-CAPSIG | Tommy Bysted, Nokia | tommy.bysted@nokia.com | Rel-6 | TSG | Paolo |  |  |  |
| 357 | 53.5 | GERAN MS Conformance test for DARP | 132d? | 2004-08-27 A | 2005-02-28 | 10% | 118.8d? | 2004-08-27 | 2005-02-28 | 132d? | 337d | finish no earlier than 2005-02-28 | G3 | 1056h | 105.6h | ARP-ConfTest | Tommy Bysted, Nokia | tommy.bysted@nokia.com | Rel-6 | TSG | Michael |  |  |  |
| 358 | 54 | **Reduction of PS service interruption in Dual Transfer Mode** | 256d? | 2003-11-21 A | 2004-11-12 | 50% | 128.82d? | 2003-11-21 | 2004-11-12 | 256d? | 413d |  | G2 | 5808h | 1892.18h | PSintDTM | Toby Proctor, Siemens | toby.proctor@roke.co.uk | Rel-6 | TSG | Gert |  |  |  |
| 359 | 54.1 | Use case and requirement definition | 111d? | 2003-11-21 A | 2004-04-23 A | 100% |  | 2003-11-21 | 2004-04-23 | 111d? |  | finish no earlier than 2004-04-23 | G2 | 888h | 888h | PSintDTM-Req | Toby Proctor, Siemens | toby.proctor@roke.co.uk | Rel-6 | TSG | Gert |  |  |  |
| 360 | 54.2 | Performance Study of Current Procedures | 111d? | 2003-11-21 A | 2004-04-23 A | 100% |  | 2003-11-21 | 2004-04-23 | 111d? |  | start no earlier than 2003-11-21 | G2 | 888h | 888h | PSintDTM-Perf | Toby Proctor, Siemens | toby.proctor@roke.co.uk | Rel-6 | TSG | Gert |  |  |  |
| 361 | 54.3 | Reduction of service interruption times and packet loss during Dual Transfer Mode and mobility procedures | 46d? | 2004-04-23 A | 2004-06-25 | 25% | 34.5d? | 2004-04-23 | 2004-06-25 | 46d? | 513d | finish no earlier than 2004-06-25 | G2 | 368h | 92h | PSintDTM-Reduct | Toby Proctor, Siemens | toby.proctor@roke.co.uk | Rel-6 | TSG | Gert |  |  |  |
| 362 | 54.4 | MS Conformance testing | 101d? | 2004-06-25 | 2004-11-12 |  |  | 2004-06-25 | 2004-11-12 | 101d? | 413d | finish no earlier than 2004-11-12 | G3 | 808h |  | PSintDTM-ConfMS |  |  | Rel-6 | TSG | Michael |  |  |  |
| 363 | 54.5 | BTS Conformance testing | 101d? | 2004-06-25 | 2004-11-12 |  |  | 2004-06-25 | 2004-11-12 | 101d? | 413d | finish no earlier than 2004-11-12 | G3 | 808h |  | PSintDTM-ConfBTS |  |  | Rel-6 | TSG | Michael |  |  |  |
| 364 | 55 | CAMEL prepay interworking with SCUDIF | 206d | 2003-12-08 A | 2004-10-05 |  | 206d | 2003-12-08 | 2004-10-05 | 206d | 441.7d |  | N4 | 1648h |  | SCCAMEL |  |  | Rel-6 |  | Kimmo |  |  |  |
| 365 | 56 | **Circuit Switched Video and Voice Service Improvements** | 210d? | 2004-01-12 A | 2004-10-29 | 53% | 99.4d? | 2004-01-12 | 2004-10-29 | 210d? | 423d |  | S1 | 8488h | 4114h | CS_VSS | John Watson, Vodafone Group |  | Rel-6 | TSG | Michael | 23.801 |  |  |
| 366 | 56.1 | Stage 1 - Requirements | 199d | 2004-01-12 A | 2004-10-14 A | 100% |  | 2004-01-12 | 2004-10-14 | 199d |  | finish no earlier than 2004-10-14 | S1 | 1592h | 1592h |  | John Watson, Vodafone Group |  | Rel-6 | TSG | Michael |  |  |  |
| 367 | 56.2 | Stage 2 Study on architecture alternatives | 155d? | 2004-01-12 A | 2004-08-13 A | 100% |  | 2004-01-12 | 2004-08-13 | 155d? |  | finish no earlier than 2004-08-13 | S2 | 1240h | 1240h |  |  |  |  |  |  |  | SP-24 |  |
| 368 | 56.3 | Stage 2 description on Redial | 130d? | 2004-05-03 A | 2004-10-29 | 85% | 19.5d? | 2004-05-03 | 2004-10-29 | 130d? | 423d | start no earlier than 2004-05-01 | S2 | 1040h | 884h |  |  |  |  |  |  | 23.903 | SP-24 |  |
| 369 | 56.4 | GERAN2 Part | 199d | 2004-01-12 | 2004-10-14 |  |  | 2004-01-12 | 2004-10-14 | 199d | 434d | start no earlier than 2004-01-12 | G2 | 1592h |  |  |  |  | Rel-6 | TSG | Gert |  |  |  |
| 370 | 56.5 | CN3 Part | 199d? | 2004-01-12 | 2004-10-14 |  |  |  |  |  | 434d | finish no earlier than 2004-10-14 | N3 | 1592h |  |  |  |  | Rel-6 |  |  |  |  |  |
| 371 | 57 | Study of Feature Interactions Requirements | 82d? | 2002-11-08 A | 2003-03-03 | 20% | 65.6d? |  |  |  | 857d | finish no earlier than 2003-03-03 | S1 | 656h | 131.2h | FINTER |  |  | Rel-6 |  |  |  |  |  |
| 372 | 58 | Rel-7 Features listed below | 1d? | 2000-01-03 | 2000-01-03 |  |  |  |  |  | 1682d |  |  |  |  |  |  |  |  |  |  |  |  |  |
| 373 | 8.5 | **Multiple Input Multiple Output antennas (MIMO)** | 719d? | 2003-03-14 A | 2005-12-15 | 12% | 634.49d? | 2003-03-14 | 2005-03-15 | 523d? | 130d |  | R1 | 23544h | 4190.4h | MIMO | Howard Huang, Lucent | hchuang@lucent.com | Rel-7 | TSG | Cesar | TR25.876,TR25.996 |  | 2468 |
| 374 | 59.1 | MIMO - Physical layer | 392d? | 2003-09-12 A | 2005-03-15 | 60% | 156.8d? | 2003-09-12 | 2005-03-15 | 393d? | 327d | finish no earlier than 2005-03-15 | R1 | 3136h | 1881.6h | MIMO-Phys | Howard Huang, Lucent | hchuang@lucent.com | Rel-7 | TSG | MCC RAN | 25.211, 25.212, 25.213, 25.214, 25.215, 25.221, 25 |  |  |
| 375 | 59.2 | MIMO - Layer 2,3 aspects | 589d? | 2003-09-12 | 2005-12-15 |  |  | 2003-09-12 | 2004-12-15 | 329d? | 130d | finish no earlier than 2005-12-15 | R2 | 4712h |  | MIMO-L23 | Howard Huang, Lucent | hchuang@lucent.com | Rel-7 | TSG | MCC RAN | TR 25.876 |  |  |
| 376 | 59.3 | MIMO - Iub/Iur Protocol Aspects | 719d? | 2003-03-14 | 2005-12-15 |  |  | 2003-03-14 | 2004-12-15 | 459d? | 130d | finish no earlier than 2005-12-15 | R3 | 5752h |  | MIMO-IurIub | Howard Huang, Lucent | hchuang@lucent.com | Rel-7 | TSG | MCC RAN |  |  |  |
| 377 | 59.4 | MIMO - RF Radio Transmission/Reception, System Performance Requirements and Conformance Testing | 524d? | 2003-12-12 A | 2005-12-15 | 5% | 497.8d? | 2003-12-12 | 2005-03-15 | 328d? | 130d | finish no earlier than 2005-12-15 | R4 | 4192h | 209.6h | MIMO-RF | Man Hung Ng, Lucent | ngm@lucent.com | Rel-7 | TSG | MCC RAN |  |  |  |

Notes:
- 353: Started
- 354: Started
- 355: Started
- 356: Started
- 357: Started
- 359: Started
- 360: Started
- 361: Started
- 362: Not started
- 363: Not started
- 371: SP-23 - To be abandoned?

| ID | WBS | Task | Duration | Start | Finish | Complete | Remaining | Baseline start | Baseline finish | Baseline duration | Total slack | Constraint | Resources | Work | Actual work | Text1 | Text4 | Text6 | Text7 | Text8 | Text2 | Text3 | Text9 | Text5 | Text12 |
| --- | --- | --- | --- | --- | --- | --- | --- | --- | --- | --- | --- | --- | --- | --- | --- | --- | --- | --- | --- | --- | --- | --- | --- | --- | --- |
| 378 | 60 | **PS domain and IMS impacts for supporting IMS Emergency calls** | 1340d? | 2000-08-14 A | 2005-09-30 | 33% | 897.82d? | 2000-08-14 | 2005-06-03 | 1255d? | 183d |  | S2 | 53584h | 15529.4h | EMC1 | Rainer Liebhart | Rel-7 | TSG | Sang-Ui |  |  |  |  |  |
| 379 | 10.1.1 | Service Requirements for IP-based emergency calls | 985d | 2000-09-18 A | 2004-06-25 A | 100% |  | 2000-09-18 | 2004-06-25 | 985d |  | finish no earlier than 2004-06-25 | S1 | 7880h | 7880h |  |  | Rel-7 |  |  | CCaR | 22.976 | 1314 |  |  |
| 380 | 60.2 | Stage 2 for IMS-level solution | 612d? | 2003-02-26 A | 2005-06-30 | 40% | 367.2d? | 2003-02-26 | 2004-12-15 | 471d? | 249d | finish no earlier than 2005-06-30 | S2 | 4896h | 1958.4h |  | Rainer Liebhart, Siemenws | Rel-7 | TSG |  |  | 23.228, 23.060, 23.002 |  |  |  |
| 381 | 60.3 | Stage 2 for GPRS-level solution | 252d? | 2004-10-14 | 2005-09-30 |  |  |  |  |  | 183d | finish no earlier than 2005-09-30 | S2 | 2016h |  |  |  | Rel-7 |  |  |  |  |  |  |  |
| 382 | 10.1 | **Emergency Call Enhancements for IP& PS Based Calls – stage 3** | 1255d | 2000-08-14 A | 2005-06-03 | 8% | 1156.47d | 2000-08-14 | 2005-06-03 | 1255d | 268d |  | N1 | 28272h | 2219.53h |  | Mr Atle Monrad, Ericsson | Rel-7 |  |  | CCaR |  | 1653 | Atle.Monrad@eto.ericsson.se |  |
| 383 | 10.1.2 | SIP emergency calls and packet emergency calls signalling flows | 1209d | 2000-10-17 A | 2005-06-03 | 16% | 1015.56d | 2000-10-17 | 2005-06-03 | 1209d | 268d | finish no earlier than 2005-06-03 | N1 | 9672h | 1547.52h |  | Mr Atle Monrad, Ericsson | Rel-7 |  |  | CCaR | TS 24.228 | 1315 | Atle.Monrad@eto.ericsson.se |  |
| 384 | 10.1.5 | Stage 3 for emergency calls and packet emergency calls in general | 1255d | 2000-08-14 | 2005-06-03 |  |  | 2000-08-14 | 2005-06-03 | 1255d | 268d | finish no earlier than 2005-06-03 | N1 | 10040h |  |  | Mr Atle Monrad, Ericsson | Rel-7 |  |  | CCaR | TS 24.229 | 1646 | Atle.Monrad@eto.ericsson.se |  |
| 385 | 61 | **Access Class Barring and Overload Protection** | 274d? | 2004-03-15 A | 2005-03-31 | 35% | 177.79d? | 2004-03-15 | 2004-11-30 | 187d? | 314d |  | S2 | 6000h | 2106.81h | ACBOP | Chris Pudney, Vodafone | Rel-7 | TSG | Sang-Ui |  | 23.898 |  |  |  |
| 386 | 61.1 | TR on Stage 2 | 274d? | 2004-03-15 A | 2005-03-31 | 61% | 106.86d? | 2004-03-15 | 2004-11-30 | 187d? | 314d | finish no earlier than 2005-03-31 | S2 | 2192h | 1337.12h |  |  |  | TSG |  |  |  |  |  |  |
| 387 | 61.2 | Deleted - Extra ACBOP information in RAN | 67d? | 2004-03-15 | 2004-06-15 |  |  | 2004-03-15 | 2004-06-15 | 67d? | 521d | start no earlier than 2004-03-15 | RP | 536h |  |  |  |  |  |  |  | 25.331 |  |  | RP-25 |
| 388 | 61.3 | Extra ACBOP information in GERAN | 67d? | 2004-03-15 | 2004-06-15 |  |  | 2004-03-15 | 2004-06-15 | 67d? | 521d | start no earlier than 2004-03-15 | GP | 536h |  |  |  |  | TSG |  |  | 44.018 |  |  |  |
| 389 | 61.4 | Deleted - Potential impact on Iu interface Overload functionality | 67d? | 2004-03-15 | 2004-06-15 |  |  | 2004-03-15 | 2004-06-15 | 67d? | 521d | start no earlier than 2004-03-15 | RP | 536h |  |  |  |  |  |  |  | 25.413 |  |  | RP-25 |
| 390 | 61.5 | Stage 3 CN aspects of ACBOP | 1d? | 2004-12-08 | 2004-12-08 |  |  |  |  |  | 395d | finish no earlier than 2004-12-08 | N1 | 8h |  |  |  |  |  |  |  |  |  |  |  |
| 391 | 62 | **USSD message delivery and transfer to USIM** | 1250d? | 2000-01-03 A | 2004-10-15 | 10% | 1120.1d? | 2004-03-18 | 2004-10-15 | 152d? | 433d |  | S1 | 2440h | 253.57h |  |  | Rel-7 | TSG | Michael |  | 22.090 |  |  |  |
| 392 | 62.1 | Stage 1 | 152d? | 2004-03-18 A | 2004-10-15 | 10% | 136.8d? | 2004-03-18 | 2004-10-15 | 152d? | 433d | start no earlier than 2004-03-18 | S1 | 1216h | 121.6h |  |  |  | TSG | Michael |  | 22.090 |  |  |  |
| 393 | 62.2 | WI on Alignment with requirements regarding USSD usage | 1d? | 2000-01-03 A | 2000-01-03 | 70% | 0.3d? |  |  |  | 1682d |  | T3 | 8h | 5.6h |  | Christophe Dubois (Axalto) |  | TSG |  |  |  |  |  |  |
| 394 | 63 | **Location Services enhancements 3** | 513d? | 2004-06-28 A | 2006-06-15 | 4% | 492.2d? | 2000-08-28 | 2004-10-29 | 1090d? | 0d |  | S2 | 11224h | 513.61h | LCS3 |  | Rel-7 |  | Sang-Ui |  | 23.271 |  |  |  |
| 395 | 63.1 | Toward A-GNSS concept | 188d? | 2004-06-28 A | 2005-03-16 | 10% | 169.2d? | 2004-06-28 | 2005-03-16 | 188d? | 325d | start no earlier than 2004-06-28 | S1 | 1504h | 150.4h | LCS3-AGNSS | Michel MONNERAT | Rel-7 | TSG | Michael |  |  |  | Michel.monnerat@space.alcatel.fr |  |
| 396 | 63.2 | **LCS for 3GPP Interworking WLAN** | 123d? | 2004-06-28 A | 2004-12-16 | 10% | 110.7d? | 2004-06-28 | 2004-12-16 | 123d? | 390d |  | S1 | 1968h | 196.8h | LCS3-IWLAN | Mike Loushine, (Telcordia) | Rel-7 | TSG | Michael |  | 22.9xx |  |  |  |
| 397 | 63.2.1 | Feasibility study on 3GPP system to Wireless Local Area Network (WLAN) Interworking with LCS | 123d? | 2004-06-28 A | 2004-12-16 | 10% | 110.7d? | 2004-06-28 | 2004-12-16 | 123d? | 390d | finish no earlier than 2004-12-16 | S2 | 984h | 98.4h |  |  | Rel-7 |  |  |  |  |  |  |  |
| 398 | 63.3 | Inclusion of Uplink TDOA UE positioning method in the UTRAN specifications | 456d? | 2004-09-15 | 2006-06-15 |  |  |  |  |  | 0d | finish no earlier than 2006-06-15 | R2 | 3648h |  | LCS3-UEPos-UTDOA | Robert Gross, TruePosition | Rel-7 | TSG | MCC_RAN |  | TS25.305, TS25.453 |  | rlgross@trueposition.com |  |
| 399 | 64 | **FS on applicability of GALILEO for LCS** | 779d? | 2002-07-08 A | 2005-06-30 | 39% | 475.24d? | 2002-07-08 | 2004-06-30 | 518d? | 249d |  | S2 | 13424h | 3804.4h |  |  | Rel-7 |  |  |  |  |  |  |  |
| 400 | 64.1 | TR on Stage 2 | 779d? | 2002-07-08 A | 2005-06-30 | 45% | 428.45d? | 2002-07-08 | 2004-06-30 | 518d? | 249d | finish no earlier than 2005-06-30 | S2 | 6232h | 2804.4h |  |  | Rel-7 |  |  |  |  |  |  |  |
| 401 | 64.2 | GERAN review of the TR | 120d? | 2003-08-25 | 2004-02-06 |  |  | 2003-08-25 | 2004-02-06 | 120d? | 613d | finish no earlier than 2004-02-06 | GP | 960h |  |  |  | Rel-7 |  |  |  |  |  |  |  |

Notes:
- 390: NEW - inserted on 2/9/2004
- 398: Approved at RP#25 as RP-040387

| ID | WBS | Task | Duration | Start | Finish | Complete | Remaining | Baseline start | Baseline finish | Baseline duration | Total slack | Constraint | Resources | Work | Actual work | Text1 | Text4 | Text5 | Text6 | Text7 | Text8 |
| --- | --- | --- | --- | --- | --- | --- | --- | --- | --- | --- | --- | --- | --- | --- | --- | --- | --- | --- | --- | --- | --- |
| 402 | 65 | **Enhancements of VGCS in public networks for communication of public authority officials** | 179d? | 2004-06-28 A | 2005-03-03 | 9% | 163.05d? | 2004-06-28 | 2004-12-16 | 123d? | 334d |  | S1 | 3640h | 324.43h | EGCS | Joerg Swetina (Siemens AG) | joerg.swetina@SIEMENS.COM | Rel-7 | TSG | Michael |
| 403 | 65.1 | Stage 1 | 123d? | 2004-06-28 A | 2004-12-16 | 20% | 98.4d? | 2004-06-28 | 2004-12-16 | 123d? | 390d | finish no earlier than 2004-12-16 | S1 | 984h | 196.8h | EGCS | Joerg Swetina (Siemens AG) | joerg.swetina@SIEMENS.COM | Rel-7 | TSG | Michael |
| 404 | 65.2 | Enhancements of VGCS in public networks for communication of public authority officials | 153d? | 2004-08-03 | 2005-03-03 |  |  |  |  |  | 334d | finish no earlier than 2005-03-03 | N1 | 1224h |  | EGCS | Siemens |  | Rel-7 | TSG | Andrijana |
| 405 | 66 | Behaviour of Multi system UEs | 188d? | 2004-06-28 A | 2005-03-16 | 10% | 169.2d? | 2004-06-28 | 2005-03-16 | 188d? | 325d | start no earlier than 2004-06-28 | S1 | 1504h | 150.4h | BMSU | D Williams (QUALCOMM) | dwilliams@qualcomm.com | Rel-7 | TSG | Michael |
| 406 | 67 | Selective Disabling of UE Capabilities | 188d? | 2004-06-28 A | 2005-03-16 | 10% | 169.2d? | 2004-06-28 | 2005-03-16 | 188d? | 325d | start no earlier than 2004-06-28 | S1 | 1504h | 150.4h | SDoUE | Nigel Barnes (Motorola Ltd) | Nigel.Barnes@motorola.com | Rel-7 | TSG | Michael |
| 407 | 68 | **FS on IMS with real time services deployment** | 384d? | 2004-06-28 A | 2005-12-15 | 12% | 337.47d? | 2004-06-28 | 2005-12-15 | 384d? | 129d |  | S1 | 7640h | 925.76h | IRTSD |  |  | Rel-7 | TSG | Michael |
| 408 | 68.1 | Combining CS calls and IMS sessions | 384d? | 2004-06-28 | 2005-12-15 |  |  | 2004-06-28 | 2005-12-15 | 384d? | 129d | start no earlier than 2004-06-28 | S1 | 3072h |  | IRTSD-CS_IMS |  |  | Rel-7 | TSG | Michael |
| 409 | 68.2 | IMS services using CS bearers | 187d? | 2004-06-28 A | 2005-03-15 | 37% | 117.81d? | 2004-06-28 | 2005-12-15 | 384d? | 326d | finish no earlier than 2005-03-15 | S2 | 1496h | 553.52h | IRTSD-IMSCS | Mark Watson (Nortel Networks) |  | Rel-7 | TSG | Sang-Ui |
| 410 | 69 | All-IP Network Feasibility Study | 188d? | 2004-06-28 A | 2005-03-16 | 20% | 150.4d? | 2004-06-28 | 2005-03-16 | 188d? | 325d | start no earlier than 2004-06-28 | S1 | 1504h | 300.8h | AIPFS | Chris Sachno (NTT DoCoMo) | c.masyu@nttdocomo.co.jp | Rel-7 | TSG | Michael |
| 411 | 70 | Enhancement of E2E QoS | 150.4d? | 2004-06-28 A | 2005-03-16 | 25% | 112.8d? | 2004-06-28 | 2005-03-16 | 188d? | 325d | finish no earlier than 2005-03-16 | S2 | 1203.2h | 300.8h | QoS7 |  |  | Rel-7 | TSG | Sang-Ui |
| 412 | 71 | **System enhancements for fixed broadband access to IMS** | 258d? | 2004-08-03 A | 2005-07-28 |  | 258d? | 2003-06-06 | 2004-08-31 | 323d? | 229d |  | S2 | 3385.6h |  | FBI |  |  | Rel-7 | TSG | Sang-Ui |
| 413 | 71.1 | Stage 2 | 206d? | 2004-10-14 A | 2005-07-28 |  | 206d? | 2003-06-06 | 2004-08-31 | 323d? | 229d | finish no earlier than 2005-07-28 | S2 | 1648h |  | FBI |  |  | Rel-7 | TSG | Sang-Ui |
| 414 | 71.2 | Protocol impact from providing IMS services via fixed broadband | 153d? | 2004-08-03 | 2005-03-03 |  |  |  |  |  | 334d | finish no earlier than 2005-03-03 | S2 | 1224h |  | FBI | Siemens |  | Rel-7 | TSG | Andrijana |
| 415 | 72 | **IMS Phase 3** | 1158d? | 2001-01-01 A | 2005-06-08 | 29% | 821.97d? |  |  |  | 265d |  | S2 | 24888h | 7125.77h |  |  |  | Rel-7 |  |  |
| 416 | 16.7 | **IMS Local services (CN WID needed)** | 1158d? | 2001-01-01 A | 2005-06-08 | 68% | 367.35d? | 2001-01-01 | 2004-06-04 | 895d? | 265d |  | S2 | 13072h | 5192.02h |  |  |  | Rel-7 |  |  |
| 417 | 16.7.1 | Stage 2 | 325d | 2001-01-01 A | 2002-03-29 A | 100% |  | 2001-01-01 | 2002-03-29 | 325d |  | start no earlier than 2001-01-01 | S2 | 2600h | 2600h |  |  |  | Rel-7 |  |  |
| 418 | 72.1.2 | Stage 3 for IMS Local services | 151d? | 2004-11-10 | 2005-06-08 |  |  | 2002-12-13 | 2004-06-04 | 386d? | 265d | finish no earlier than 2005-06-08 | N1 | 1208h |  |  | Keith Drage, Lucent | drage@lucent.com | Rel-7 |  |  |
| 419 | 72.2 | Mp (MRFC - MRFP) interface - CN4 Part (check supporting companies) | 644d | 2002-12-13 | 2005-06-01 |  |  | 2002-12-13 | 2004-11-30 | 513d | 270d | finish no earlier than 2005-06-01 | N4 | 5152h |  | IMS-CCR-Mp |  |  | Rel-6 |  |  |
| 420 | 73 | **Improvements of Radio Interface** | 196d? | 2004-09-15 | 2005-06-15 |  |  | 2000-08-14 | 2004-09-15 | 1068d | 260d |  | RP | 1856h |  | RInImp |  |  | Rel-7 | TSG | Cesar |
| 421 | 73.1 | UMTS 2.6 GHz | 196d? | 2004-09-15 | 2005-06-15 |  |  |  |  |  | 260d | finish no earlier than 2005-06-15 | R4 | 1568h |  | RInImp-UMTS2600 | Jussi Numminen, Nokia | jussi.numminen@nokia.com | Rel-7 | TSG | MCC_RAN |
| 422 | 74 | **7.68Mcps TDD option** | 390d? | 2004-09-15 | 2006-03-15 |  |  |  |  |  | 66d |  | RP | 14592h |  | VHCRTDD | Martin Beale, IPWireless | mbeale@ipwireless.com | Rel-7 | TSG | MCC_RAN |
| 423 | 74.1 | 7.68Mcps TDD option: Stage 2 | 261d? | 2004-09-15 | 2005-09-15 |  |  |  |  |  | 195d | finish no earlier than 2005-09-15 | R1 | 2088h |  | VHCRTDD-Stage2 | Martin Beale, IPWireless | mbeale@ipwireless.com | Rel-7 | TSG | MCC_RAN |
| 424 | 74.2 | 7.68Mcps TDD option: Physical Layer | 261d? | 2004-09-15 | 2005-09-15 |  |  |  |  |  | 195d | finish no earlier than 2005-09-15 | R1 | 2088h |  | VHCRTDD-Phys | Martin Beale, IPWireless | mbeale@ipwireless.com | Rel-7 | TSG | MCC_RAN |
| 425 | 74.3 | 7.68Mcps TDD option: Layer 2 and layer 3 protocol aspects | 261d? | 2004-09-15 | 2005-09-15 |  |  |  |  |  | 195d | finish no earlier than 2005-09-15 | R2 | 2088h |  | VHCRTDD-L23 | Derek Richards, IPWireless | drichards@ipwireless.com | Rel-7 | TSG | MCC_RAN |
| 426 | 74.4 | 7.68Mcps TDD option: UTRAN Iub/Iur Protocol Aspects | 261d? | 2004-09-15 | 2005-09-15 |  |  |  |  |  | 195d | finish no earlier than 2005-09-15 | R3 | 2088h |  | VHCRTDD-IurIub | Peter Legg, IPWireless | plegg@ipwireless.com | Rel-7 | TSG | MCC_RAN |
| 427 | 74.5 | 7.68Mcps TDD option: RF Radio Transmission/ Reception, System Performance Requirements and Conformance Testing | 390d? | 2004-09-15 | 2006-03-15 |  |  |  |  |  | 66d | finish no earlier than 2006-03-15 | R4 | 3120h |  | VHCRTDD-RF | Shin Horng Wong, IPWireless | shwong@ipwireless.com | Rel-7 | TSG | MCC_RAN |
| 428 | 75 | Support of SMS and MMS over generic 3GPP IP access | 118d? | 2004-10-14 | 2005-03-28 |  |  |  |  |  | 317d | finish no earlier than 2005-03-28 | S2 | 944h |  | SMSIP |  |  | Rel-7 | TSG |  |
| 429 | 76 | Evolution of Policy Control and Charging | 315d? | 2004-10-14 | 2005-12-28 |  |  |  |  |  | 120d | finish no earlier than 2005-12-28 | S2 | 2520h |  | PCC |  |  | Rel-7 | TSG |  |
| 430 | 77 | Support for GNSS in GERAN (Global Navigation Satellite System) | 161d? | 2004-08-27 | 2005-04-08 |  |  |  |  |  | 308d | start no earlier than 2004-08-27 | GP | 1288h |  | GNSS | Richard Couty, ALCATEL SA | richard.couty@space.alcatel.fr | Rel-7 | TSG | Paolo |
| 431 | 78 | FS of enhanced support of Video Telephony | 111d? | 2004-08-27 | 2005-01-28 |  |  |  |  |  | 358d | finish no earlier than 2005-01-28 | GP | 888h |  | VIDGER | Stefan Eriksson, Ericsson | stefan.g.eriksson@ericsson.com | Rel-7 | TSG | Paolo |

Notes:
- 402: Text3: 42.068, 43.068
- 403: Text3: 42.068, 43.068
- 404: WI sent to NP#25 for approval / Text3: 43.068, 44.068, 24.008, 29.002
- 405: Text3: 22.xxx
- 406: Text3: 22.xxx
- 408: Text3: 22.abc, 23.899
- 409: Text3: 23.899
- 410: Text3: 22.978
- 414: WI sent to NP#25 for approval / Text3: new TR, 24.229, 29.229, 29.163, 29.209
- 416: Text3: 23.228
- 419: 27/11/2002 KK: WID approved at CN#18 (NP-020601)........
- 420: This is a generic feature without particular end date
- 421: Approved at RP#25 as RP-040377 / Text3: TS25.101, TS25.104, TS25.133, TS25.141, TS25.331, TS25.942, TS25.306, TS25.307, TS34.121
- 422: Approved at RP#25 as RP-040365
- 423: Approved at RP#25 as RP-040365 / Text3: New specification
- 424: Approved at RP#25 as RP-040365 / Text3: TS25.221, TS25.222, TS25.223, TS25.224,TS25.225
- 425: Approved at RP#25 as RP-040365 / Text3: TS25.301, TS25.302, TS25.305, TS25.306, TS25.321, TS25.331
- 426: Approved at RP#25 as RP-040365 / Text3: TS25.401, TS25.420, TS25.423, TS25.425, TS25.427, TS25.430, TS25.433, TS25.435
- 427: Approved at RP#25 as RP-040365 / Text3: TS25.102, TS25.105, TS25.123, TS25.133, TS25.142
- 431: Feasibility Study

| ID | WBS | Task | Duration | Start | Finish | Complete | Remaining | Total slack | Constraint | Resources | Work | Actual work | Text1 | Text4 | Text6 | Text7 | Text8 | Text3 | Text5 |
| --- | --- | --- | --- | --- | --- | --- | --- | --- | --- | --- | --- | --- | --- | --- | --- | --- | --- | --- | --- |
| 432 | 79 | **Generic Access to A/Gb Interface (GAAI)** | 261d? | 2004-06-25 A | 2005-06-24 | 8% | 240.44d? | 253d |  | GP | 6760h | 532.47h | GAAI | Motorola | Rel-7 | TSG | Paolo |  |  |
| 433 | 79.1 | FS on GAAI | 46d? | 2004-06-25 A | 2004-08-27 A | 100% |  |  | finish no earlier than 2004-08-27 | GP | 368h | 368h | GAAG | Motorola | Rel-7 | TSG | Paolo | TR 43.901 |  |
| 434 | 79.2 | GAAI – Stage 2 | 161d? | 2004-08-27 | 2005-04-08 |  |  | 308d | finish no earlier than 2005-04-08 | GP | 1288h |  | GAAI-Stage2 |  | Rel-7 | TSG |  |  |  |
| 435 | 79.3 | GAAI – Stage 3 | 161d? | 2004-08-27 | 2005-04-08 |  |  | 308d | finish no earlier than 2005-04-08 | GP | 1288h |  | GAAI-Stage3 |  | Rel-7 | TSG |  |  |  |
| 436 | 79.4 | MS Conformance Test for GAAI | 216d? | 2004-08-27 | 2005-06-24 |  |  | 253d | finish no earlier than 2005-06-24 | GP | 1728h |  | GAAI-CT |  | Rel-7 | TSG |  |  |  |
| 437 | 80 | Enhancements of VGCS in public networks for communication of public authority officials | 80.5d? | 2004-12-17 | 2005-04-08 |  |  | 308d | finish no earlier than 2005-04-08 | GP;; G2 | 1288h |  | EVGCS | Ken Isaacs (Siemens) | Rel-7 | TSG | Paolo |  | kenneth.isaacs@roke.co.uk |

Notes:
- 433: Feasibility Study
